# Project Catalyst — AI Transformation Program

Schedule from MS Project XML, 2026-08-17 to 2029-08-29, status date 2026-09-11.
ACME Highland Health

## Calendars

- Standard: Mon-Fri 08:00-12:00, 13:00-17:00; Sat-Sun off.

## Resources

| Resource | Group |
| --- | --- |
| Unassigned |  |
| C. Tyrrell | Program Leadership & PMO |
| M. Kavanagh | Executive Steering & Governance Board |
| T. Valdez | Program Leadership & PMO |
| K. Anderson | Program Leadership & PMO |
| J. Wright | Program Leadership & PMO |
| D. Lee | Program Leadership & PMO |
| D. Ferraro | HR / Workforce Planning & Org Design |
| F. Bianchi | HR / Workforce Planning & Org Design |
| E. Marsh | HR / Workforce Planning & Org Design |
| G. Solberg | HR / Workforce Planning & Org Design |
| C. Johnson | HR / Workforce Planning & Org Design |
| H. Rutherford | HR / Workforce Planning & Org Design |
| M. Torres | Program Leadership & PMO |
| P. Davis | Program Leadership & PMO |
| R. Castellanos | Corporate Communications / PR |
| B. Sullivan | Corporate Communications / PR |
| S. Chen | Program Leadership & PMO |
| R. Johnson | Program Leadership & PMO |
| N. Gupta | Program Leadership & PMO |
| L. Martinez | Program Leadership & PMO |
| H. Kim | Program Leadership & PMO |
| V. Patel | Program Leadership & PMO |
| G. Brown | Program Leadership & PMO |
| Q. Wilson | Program Leadership & PMO |
| A. Rodriguez | Program Finance |
| B. Halvorsen | Program Finance |
| C. Restrepo | Program Finance |
| D. Vartan | Program Finance |
| E. Talbot | Program Finance |
| F. Sondheim | Program Finance |
| K. Okonkwo | Legal |
| M. Bernstein | Legal |
| D. Flores | Legal |
| R. Thorne | Legal |
| N. Harris | Legal |
| S. Patel | Legal |
| L. Huang | Compliance |
| R. Kimani | Compliance |
| C. Morrison | Compliance |
| J. Martinez | Compliance |
| T. Jackson | Compliance |
| B. Cho | Compliance |
| U. Kowalski | Compliance |
| M. Osei | SOX / Financial Controls |
| N. Brennan | SOX / Financial Controls |
| O. Fairweather | SOX / Financial Controls |
| K. Williams | SOX / Financial Controls |
| P. Whitcomb | SOX / Financial Controls |
| Q. Marchetti | SOX / Financial Controls |
| G. Ainsley | Vendor / SaaS Partner Management |
| H. Prescott | Vendor / SaaS Partner Management |
| L. Park | Vendor / SaaS Partner Management |
| I. Merchant | Vendor / SaaS Partner Management |
| S. Halloway | Corporate Communications / PR |
| T. Ainslie | Corporate Communications / PR |
| W. Kumar | Data & Cloud AI Platform Foundation |
| J. Restrepo | Data & Cloud AI Platform Foundation |
| K. Vartan | Data & Cloud AI Platform Foundation |
| N. Winthrop | Cybersecurity / InfoSec |
| O. Castillo | Cybersecurity / InfoSec |
| P. Halstead | Cybersecurity / InfoSec |
| Q. Beaumont | Cybersecurity / InfoSec |
| M. Hassan | Cybersecurity / InfoSec |
| A. Prescott | IT Operations / Infrastructure |
| B. Fairweather | IT Operations / Infrastructure |
| C. Sondheim | IT Operations / Infrastructure |
| D. Marchetti | IT Operations / Infrastructure |
| H. Nakamura | IT Operations / Infrastructure |
| E. Whitcomb | IT Operations / Infrastructure |
| F. Talbot | IT Operations / Infrastructure |
| G. Restrepo | IT Operations / Infrastructure |
| H. Vartan | IT Operations / Infrastructure |
| R. Fontaine | Cybersecurity / InfoSec |
| S. Vasquez | Cybersecurity / InfoSec |
| T. Delvecchio | Cybersecurity / InfoSec |
| U. Kandel | Cybersecurity / InfoSec |
| V. Redmond | Cybersecurity / InfoSec |
| I. Halvorsen | IT Operations / Infrastructure |
| L. Sondheim | Data & Cloud AI Platform Foundation |
| M. Marchetti | Data & Cloud AI Platform Foundation |
| N. Whitcomb | Data & Cloud AI Platform Foundation |
| O. Talbot | Data & Cloud AI Platform Foundation |
| P. Restrepo2 | Data & Cloud AI Platform Foundation |
| Q. Halvorsen2 | Data & Cloud AI Platform Foundation |
| R. Bianchi | Data & Cloud AI Platform Foundation |
| S. Fitzgerald | Data & Cloud AI Platform Foundation |
| T. Andersen | Data & Cloud AI Platform Foundation |
| U. Kowalczyk2 | Data & Cloud AI Platform Foundation |
| V. Delvecchio2 | Data & Cloud AI Platform Foundation |
| W. Solberg2 | Data & Cloud AI Platform Foundation |
| X. Nakashima2 | Data & Cloud AI Platform Foundation |
| Y. Winfield2 | Data & Cloud AI Platform Foundation |
| Z. Achebe2 | Data & Cloud AI Platform Foundation |
| A. Larsen2 | Data & Cloud AI Platform Foundation |
| B. Sorensen2 | Data & Cloud AI Platform Foundation |
| N. Achterberg | Data Privacy Office |
| O. Whitlock | Data Privacy Office |
| P. Sandoval | Data Privacy Office |
| Q. Beckham | Data Privacy Office |
| E. Sato | Data Privacy Office |
| N. Alvarado4 | Customer Service Operations |
| O. Whitby7 | Customer Service Operations |
| P. Okoro7 | Customer Service Operations |
| Q. Beaumont5 | Customer Service Operations |
| M. Washington (CustOps) |  |
| S. Delvecchio6 | Customer Service Operations |
| T. Solberg6 | Customer Service Operations |
| R. Kowalczyk6 | Customer Service Operations |
| U. Nakashima6 | Customer Service Operations |
| X. Larsen6 | Customer Service Operations |
| V. Winfield6 | Customer Service Operations |
| W. Achebe6 | Customer Service Operations |
| S. Khurana | AI Governance & CoE |
| A. Reyes | AI Governance & CoE |
| J. Ferraro | AI Governance & CoE |
| M. Delacroix | AI Governance & CoE |
| C. Alvarez | AI Governance & CoE |
| T. Nakamura | AI Governance & CoE |
| R. Osei | AI Governance & CoE |
| P. Singh | AI Governance & CoE |
| V. Castellano | AI Governance & CoE |
| L. Whitfield | AI Governance & CoE |
| K. Novak | AI Governance & CoE |
| D. Ibrahim | AI Governance & CoE |
| F. Okonkwo | Enterprise Architecture |
| G. Petrova | Enterprise Architecture |
| H. Delgado | Enterprise Architecture |
| I. Suzuki | Enterprise Architecture |
| D. Chen | Enterprise Architecture |
| J. Kowalczyk | Enterprise Architecture |
| L. Fitzgerald | Enterprise Architecture |
| K. Andersen | Enterprise Architecture |
| P. Okafor | Independent Model Validation |
| W. Achebe | Independent Model Validation |
| X. Sorensen | Independent Model Validation |
| Y. Larsen | Independent Model Validation |
| Z. Winfield (IMV) |  |
| A. Kessler | Independent Model Validation |
| G. Okonkwo | Change Management & Training |
| B. Prescott | Change Management & Training |
| C. Whitfield | Change Management & Training |
| D. Solis | Change Management & Training |
| E. Winthrop | Change Management & Training |
| F. Bennett | Claims & Prior Authorization AI (BRD-01) |
| C. Garcia2 | Claims & Prior Authorization AI (BRD-01) |
| D. Thompson2 | Claims & Prior Authorization AI (BRD-01) |
| E. Washington2 | Claims & Prior Authorization AI (BRD-01) |
| F. Ferraro2 | Claims & Prior Authorization AI (BRD-01) |
| G. Delacroix2 | Claims & Prior Authorization AI (BRD-01) |
| H. Vartan2 | Claims & Prior Authorization AI (BRD-01) |
| K. Okoro | Clinical / Medical Policy & Informatics |
| L. Delacroix | Clinical / Medical Policy & Informatics |
| Dr. J. Whitby | Clinical / Medical Policy & Informatics |
| Dr. I. Alvarado | Clinical / Medical Policy & Informatics |
| Dr. N. Patel | Clinical / Medical Policy & Informatics |
| I. Halvorsen2 | Claims & Prior Authorization AI (BRD-01) |
| J. Nakamura2 | Claims & Prior Authorization AI (BRD-01) |
| K. Okoro2 | Claims & Prior Authorization AI (BRD-01) |
| L. Whitby2 | Claims & Prior Authorization AI (BRD-01) |
| M. Beaumont2 | Claims & Prior Authorization AI (BRD-01) |
| J. Lee | Customer UX / Design |
| U. Marchetti | Customer UX / Design |
| V. Okwuosa | Customer UX / Design |
| W. Pham | Customer UX / Design |
| X. Delgado | Customer UX / Design |
| Y. Nakashima (UX) |  |
| Z. Fairbanks | Customer UX / Design |
| A. Castillo | Customer UX / Design |
| M. Beaumont | Clinical / Medical Policy & Informatics |
| N. Kowalczyk3 | Claims & Prior Authorization AI (BRD-01) |
| O. Delvecchio3 | Claims & Prior Authorization AI (BRD-01) |
| P. Solberg3 | Claims & Prior Authorization AI (BRD-01) |
| Q. Nakashima3 | Claims & Prior Authorization AI (BRD-01) |
| R. Winfield3 | Claims & Prior Authorization AI (BRD-01) |
| S. Achebe3 | Claims & Prior Authorization AI (BRD-01) |
| T. Larsen3 | Claims & Prior Authorization AI (BRD-01) |
| U. Sorensen3 | Claims & Prior Authorization AI (BRD-01) |
| V. Kessler2 | Claims & Prior Authorization AI (BRD-01) |
| W. Rutherford2 | Claims & Prior Authorization AI (BRD-01) |
| X. Alvarado2 | Claims & Prior Authorization AI (BRD-01) |
| Y. Whitby3 | Claims & Prior Authorization AI (BRD-01) |
| Z. Okoro3 | Claims & Prior Authorization AI (BRD-01) |
| A. Delacroix3 | Claims & Prior Authorization AI (BRD-01) |
| B. Vartan3 | Claims & Prior Authorization AI (BRD-01) |
| C. Halvorsen3 | Claims & Prior Authorization AI (BRD-01) |
| V. Müller | QA & Testing |
| J. Bennett | QA & Testing |
| K. Garcia | QA & Testing |
| L. Thompson | QA & Testing |
| M. Washington (QA) |  |
| N. Ferraro | QA & Testing |
| O. Delacroix | QA & Testing |
| P. Vartan | QA & Testing |
| Q. Halvorsen | QA & Testing |
| R. Nakamura | QA & Testing |
| S. Okoro | QA & Testing |
| T. Whitby | QA & Testing |
| U. Beaumont | QA & Testing |
| V. Kowalczyk | QA & Testing |
| W. Delvecchio | QA & Testing |
| X. Solberg | QA & Testing |
| Y. Nakashima (QA) |  |
| Z. Winfield (QA) |  |
| Y. Sorensen6 | User Acceptance Testing (UAT) |
| Z. Kessler5 | User Acceptance Testing (UAT) |
| A. Rutherford5 | User Acceptance Testing (UAT) |
| B. Alvarado5 | User Acceptance Testing (UAT) |
| C. Whitby8 | User Acceptance Testing (UAT) |
| D. Okoro8 | User Acceptance Testing (UAT) |
| E. Beaumont6 | User Acceptance Testing (UAT) |
| F. Kowalczyk7 | User Acceptance Testing (UAT) |
| G. Delvecchio7 | User Acceptance Testing (UAT) |
| H. Solberg7 | User Acceptance Testing (UAT) |
| I. Nakashima7 | User Acceptance Testing (UAT) |
| F. Achebe | Change Management & Training |
| H. Kandel | Change Management & Training |
| I. Redmond | Change Management & Training |
| X. Garcia | Member & Provider Experience AI (BRD-02) |
| D. Nakamura3 | Member & Provider Experience AI (BRD-02) |
| E. Okoro4 | Member & Provider Experience AI (BRD-02) |
| F. Whitby4 | Member & Provider Experience AI (BRD-02) |
| G. Beaumont3 | Member & Provider Experience AI (BRD-02) |
| H. Kowalczyk4 | Member & Provider Experience AI (BRD-02) |
| I. Delvecchio4 | Member & Provider Experience AI (BRD-02) |
| J. Solberg4 | Member & Provider Experience AI (BRD-02) |
| K. Nakashima4 | Member & Provider Experience AI (BRD-02) |
| L. Winfield4 | Member & Provider Experience AI (BRD-02) |
| M. Achebe4 | Member & Provider Experience AI (BRD-02) |
| N. Larsen4 | Member & Provider Experience AI (BRD-02) |
| O. Sorensen4 | Member & Provider Experience AI (BRD-02) |
| P. Kessler3 | Member & Provider Experience AI (BRD-02) |
| S. Whitby5 | Member & Provider Experience AI (BRD-02) |
| T. Okoro5 | Member & Provider Experience AI (BRD-02) |
| Q. Rutherford3 | Member & Provider Experience AI (BRD-02) |
| R. Alvarado3 | Member & Provider Experience AI (BRD-02) |
| U. Delacroix4 | Member & Provider Experience AI (BRD-02) |
| V. Vartan4 | Member & Provider Experience AI (BRD-02) |
| W. Halvorsen4 | Member & Provider Experience AI (BRD-02) |
| Y. Nakamura4 | Member & Provider Experience AI (BRD-02) |
| Z. Thompson | Underwriting & Risk AI (BRD-03) |
| A. Okoro6 | Underwriting & Risk AI (BRD-03) |
| B. Whitby6 | Underwriting & Risk AI (BRD-03) |
| C. Beaumont4 | Underwriting & Risk AI (BRD-03) |
| D. Kowalczyk5 | Underwriting & Risk AI (BRD-03) |
| E. Delvecchio5 | Underwriting & Risk AI (BRD-03) |
| F. Solberg5 | Underwriting & Risk AI (BRD-03) |
| G. Nakashima5 | Underwriting & Risk AI (BRD-03) |
| H. Winfield5 | Underwriting & Risk AI (BRD-03) |
| I. Achebe5 | Underwriting & Risk AI (BRD-03) |
| J. Larsen5 | Underwriting & Risk AI (BRD-03) |
| K. Sorensen5 | Underwriting & Risk AI (BRD-03) |
| L. Kessler4 | Underwriting & Risk AI (BRD-03) |
| M. Rutherford4 | Underwriting & Risk AI (BRD-03) |

## Schedule

| ID | WBS | Task | Duration | Start | Finish | Predecessors | Complete | Resources |
| --- | --- | --- | --- | --- | --- | --- | --- | --- |
| 1 | 1.0 | **Program Management & PMO** | 770d | 2026-08-17 | 2029-07-27 |  | 6% |  |
| 2 | 1.0.1 | **Program Initiation & Mobilization** | 49d | 2026-08-17 | 2026-10-22 |  | 41% |  |
| 3 | 1.0.1.1 | Charter finalization & approval | 6d | 2026-08-17 | 2026-08-24 |  | 100% | C. Tyrrell; M. Kavanagh [15%] |
| 4 | 1.0.1.2 | Program kickoff & team mobilization | 5d | 2026-08-25 | 2026-08-31 | 3 | 100% | T. Valdez; K. Anderson; M. Kavanagh [15%] |
| 5 | 1.0.1.3 | **PMO stand-up & tooling setup** | 8d | 2026-09-01 | 2026-09-10 |  | 100% |  |
| 6 | 1.0.1.3.1 | Schedule & EVM tooling | 4d | 2026-09-01 | 2026-09-04 | 4 | 100% | K. Anderson; J. Wright |
| 7 | 1.0.1.3.2 | Collaboration & RAIDD tooling | 4d | 2026-09-07 | 2026-09-10 | 6 | 100% | J. Wright; D. Lee |
| 8 | 1.0.1.4 | **Staffing ramp & onboarding** | 10d | 2026-09-11 | 2026-09-24 |  | 10% |  |
| 9 | 1.0.1.4.1 | Onshore staffing & onboarding | 5d | 2026-09-11 | 2026-09-17 | 5 | 20% | D. Ferraro; F. Bianchi; E. Marsh [90%]; G. Solberg [80%]; C. Johnson [20%] |
| 10 | 1.0.1.4.2 | Offshore staffing & onboarding | 5d | 2026-09-18 | 2026-09-24 | 9 |  | D. Ferraro; E. Marsh [90%]; G. Solberg [80%]; H. Rutherford [70%]; C. Johnson [20%] |
| 11 | 1.0.1.5 | Integrated baseline schedule & budget | 8d | 2026-09-25 | 2026-10-06 | 8 |  | D. Lee; M. Torres; P. Davis |
| 12 | 1.0.1.6 | Communications & stakeholder plan | 6d | 2026-10-07 | 2026-10-14 | 11 |  | R. Castellanos [90%]; B. Sullivan [30%] |
| 13 | 1.0.1.7 | RAIDD register & risk baseline | 6d | 2026-10-15 | 2026-10-22 | 12 |  | P. Davis; S. Chen |
| 14 | 1.0.2 | **Steering & Governance Reporting** | 759d | 2026-09-01 | 2029-07-27 |  | 4% |  |
| 15 | 1.0.2.1 | Steering board prep & reporting — Y1 Q1 | 20d | 2026-09-01 | 2026-09-28 |  | 45% | S. Chen; R. Johnson [50%] |
| 16 | 1.0.2.2 | Steering board prep & reporting — Y1 Q2 | 20d | 2026-12-01 | 2026-12-28 |  |  | N. Gupta; R. Johnson [50%] |
| 17 | 1.0.2.3 | Steering board prep & reporting — Y1 Q3 | 20d | 2027-03-01 | 2027-03-26 |  |  | N. Gupta; L. Martinez [80%] |
| 18 | 1.0.2.4 | Steering board prep & reporting — Y1 Q4 | 20d | 2027-06-01 | 2027-06-28 |  |  | H. Kim; L. Martinez [80%] |
| 19 | 1.0.2.5 | Steering board prep & reporting — Y2 Q1 | 20d | 2027-10-01 | 2027-10-28 |  |  | H. Kim; V. Patel [80%] |
| 20 | 1.0.2.6 | Steering board prep & reporting — Y2 Q2 | 20d | 2028-01-03 | 2028-01-28 |  |  | V. Patel [80%]; G. Brown [60%] |
| 21 | 1.0.2.7 | Steering board prep & reporting — Y2 Q3 | 20d | 2028-04-03 | 2028-04-28 |  |  | Q. Wilson [80%]; G. Brown [60%] |
| 22 | 1.0.2.8 | Steering board prep & reporting — Y2 Q4 | 20d | 2028-07-03 | 2028-07-28 |  |  | C. Tyrrell; Q. Wilson [80%] |
| 23 | 1.0.2.9 | Steering board prep & reporting — Y3 Q1 | 20d | 2028-10-02 | 2028-10-27 |  |  | C. Tyrrell; M. Kavanagh [15%] |
| 24 | 1.0.2.10 | Steering board prep & reporting — Y3 Q2 | 20d | 2029-01-02 | 2029-01-29 |  |  | T. Valdez; M. Kavanagh [15%] |
| 25 | 1.0.2.11 | Steering board prep & reporting — Y3 Q3 | 20d | 2029-04-02 | 2029-04-27 |  |  | T. Valdez; K. Anderson |
| 26 | 1.0.2.12 | Steering board prep & reporting — Y3 Q4 | 20d | 2029-07-02 | 2029-07-27 |  |  | K. Anderson; J. Wright |

| ID | WBS | Task | Duration | Start | Finish | Complete | Resources |
| --- | --- | --- | --- | --- | --- | --- | --- |
| 27 | 1.0.3 | **EVM, Forecasting & Financial Management** | 759d | 2026-09-01 | 2029-07-27 | 4% |  |
| 28 | 1.0.3.1 | EVM, forecast & financial reporting — Y1 Q1 | 20d | 2026-09-01 | 2026-09-28 | 45% | A. Rodriguez; B. Halvorsen |
| 29 | 1.0.3.2 | EVM, forecast & financial reporting — Y1 Q2 | 20d | 2026-12-01 | 2026-12-28 |  | B. Halvorsen; C. Restrepo |
| 30 | 1.0.3.3 | EVM, forecast & financial reporting — Y1 Q3 | 20d | 2027-03-01 | 2027-03-26 |  | C. Restrepo; D. Vartan |
| 31 | 1.0.3.4 | EVM, forecast & financial reporting — Y1 Q4 | 20d | 2027-06-01 | 2027-06-28 |  | D. Vartan; E. Talbot [90%] |
| 32 | 1.0.3.5 | EVM, forecast & financial reporting — Y2 Q1 | 20d | 2027-10-01 | 2027-10-28 |  | E. Talbot [90%]; F. Sondheim [80%] |
| 33 | 1.0.3.6 | EVM, forecast & financial reporting — Y2 Q2 | 20d | 2028-01-03 | 2028-01-28 |  | A. Rodriguez; F. Sondheim [80%] |
| 34 | 1.0.3.7 | EVM, forecast & financial reporting — Y2 Q3 | 20d | 2028-04-03 | 2028-04-28 |  | A. Rodriguez; B. Halvorsen |
| 35 | 1.0.3.8 | EVM, forecast & financial reporting — Y2 Q4 | 20d | 2028-07-03 | 2028-07-28 |  | B. Halvorsen; C. Restrepo |
| 36 | 1.0.3.9 | EVM, forecast & financial reporting — Y3 Q1 | 20d | 2028-10-02 | 2028-10-27 |  | C. Restrepo; D. Vartan |
| 37 | 1.0.3.10 | EVM, forecast & financial reporting — Y3 Q2 | 20d | 2029-01-02 | 2029-01-29 |  | D. Vartan; E. Talbot [90%] |
| 38 | 1.0.3.11 | EVM, forecast & financial reporting — Y3 Q3 | 20d | 2029-04-02 | 2029-04-27 |  | E. Talbot [90%]; F. Sondheim [80%] |
| 39 | 1.0.3.12 | EVM, forecast & financial reporting — Y3 Q4 | 20d | 2029-07-02 | 2029-07-27 |  | A. Rodriguez; F. Sondheim [80%] |
| 40 | 1.0.4 | **RAIDD & Change Control Operations** | 759d | 2026-09-01 | 2029-07-27 | 4% |  |
| 41 | 1.0.4.1 | RAIDD review & change-control operations — Y1 Q1 | 20d | 2026-09-01 | 2026-09-28 | 45% | J. Wright; D. Lee |
| 42 | 1.0.4.2 | RAIDD review & change-control operations — Y1 Q2 | 20d | 2026-12-01 | 2026-12-28 |  | D. Lee; M. Torres |
| 43 | 1.0.4.3 | RAIDD review & change-control operations — Y1 Q3 | 20d | 2027-03-01 | 2027-03-26 |  | M. Torres; P. Davis |
| 44 | 1.0.4.4 | RAIDD review & change-control operations — Y1 Q4 | 20d | 2027-06-01 | 2027-06-28 |  | P. Davis; S. Chen |
| 45 | 1.0.4.5 | RAIDD review & change-control operations — Y2 Q1 | 20d | 2027-10-01 | 2027-10-28 |  | S. Chen; R. Johnson [50%] |
| 46 | 1.0.4.6 | RAIDD review & change-control operations — Y2 Q2 | 20d | 2028-01-03 | 2028-01-28 |  | N. Gupta; R. Johnson [50%] |
| 47 | 1.0.4.7 | RAIDD review & change-control operations — Y2 Q3 | 20d | 2028-04-03 | 2028-04-28 |  | N. Gupta; L. Martinez [80%] |
| 48 | 1.0.4.8 | RAIDD review & change-control operations — Y2 Q4 | 20d | 2028-07-03 | 2028-07-28 |  | H. Kim; L. Martinez [80%] |
| 49 | 1.0.4.9 | RAIDD review & change-control operations — Y3 Q1 | 20d | 2028-10-02 | 2028-10-27 |  | H. Kim; V. Patel [80%] |
| 50 | 1.0.4.10 | RAIDD review & change-control operations — Y3 Q2 | 20d | 2029-01-02 | 2029-01-29 |  | V. Patel [80%]; G. Brown [60%] |
| 51 | 1.0.4.11 | RAIDD review & change-control operations — Y3 Q3 | 20d | 2029-04-02 | 2029-04-27 |  | Q. Wilson [80%]; G. Brown [60%] |
| 52 | 1.0.4.12 | RAIDD review & change-control operations — Y3 Q4 | 20d | 2029-07-02 | 2029-07-27 |  | C. Tyrrell; Q. Wilson [80%] |

| ID | WBS | Task | Duration | Start | Finish | Complete | Resources |
| --- | --- | --- | --- | --- | --- | --- | --- |
| 53 | 1.0.5 | **Schedule & Performance Management** | 759d | 2026-09-01 | 2029-07-27 | 4% |  |
| 54 | 1.0.5.1 | Schedule maintenance & critical-path analysis — Y1 Q1 | 20d | 2026-09-01 | 2026-09-28 | 45% | C. Tyrrell; M. Kavanagh [15%] |
| 55 | 1.0.5.2 | Schedule maintenance & critical-path analysis — Y1 Q2 | 20d | 2026-12-01 | 2026-12-28 |  | T. Valdez; M. Kavanagh [15%] |
| 56 | 1.0.5.3 | Schedule maintenance & critical-path analysis — Y1 Q3 | 20d | 2027-03-01 | 2027-03-26 |  | T. Valdez; K. Anderson |
| 57 | 1.0.5.4 | Schedule maintenance & critical-path analysis — Y1 Q4 | 20d | 2027-06-01 | 2027-06-28 |  | K. Anderson; J. Wright |
| 58 | 1.0.5.5 | Schedule maintenance & critical-path analysis — Y2 Q1 | 20d | 2027-10-01 | 2027-10-28 |  | J. Wright; D. Lee |
| 59 | 1.0.5.6 | Schedule maintenance & critical-path analysis — Y2 Q2 | 20d | 2028-01-03 | 2028-01-28 |  | D. Lee; M. Torres |
| 60 | 1.0.5.7 | Schedule maintenance & critical-path analysis — Y2 Q3 | 20d | 2028-04-03 | 2028-04-28 |  | M. Torres; P. Davis |
| 61 | 1.0.5.8 | Schedule maintenance & critical-path analysis — Y2 Q4 | 20d | 2028-07-03 | 2028-07-28 |  | P. Davis; S. Chen |
| 62 | 1.0.5.9 | Schedule maintenance & critical-path analysis — Y3 Q1 | 20d | 2028-10-02 | 2028-10-27 |  | S. Chen; R. Johnson [50%] |
| 63 | 1.0.5.10 | Schedule maintenance & critical-path analysis — Y3 Q2 | 20d | 2029-01-02 | 2029-01-29 |  | N. Gupta; R. Johnson [50%] |
| 64 | 1.0.5.11 | Schedule maintenance & critical-path analysis — Y3 Q3 | 20d | 2029-04-02 | 2029-04-27 |  | N. Gupta; L. Martinez [80%] |
| 65 | 1.0.5.12 | Schedule maintenance & critical-path analysis — Y3 Q4 | 20d | 2029-07-02 | 2029-07-27 |  | H. Kim; L. Martinez [80%] |
| 66 | 1.0.6 | **Legal & Contract Management** | 759d | 2026-09-01 | 2029-07-27 | 4% |  |
| 67 | 1.0.6.1 | Legal counsel, contracts & IP review — Y1 Q1 | 20d | 2026-09-01 | 2026-09-28 | 45% | K. Okonkwo; M. Bernstein; D. Flores [80%]; R. Thorne [20%] |
| 68 | 1.0.6.2 | Legal counsel, contracts & IP review — Y1 Q2 | 20d | 2026-12-01 | 2026-12-28 |  | N. Harris; S. Patel [90%]; D. Flores [80%]; R. Thorne [20%] |
| 69 | 1.0.6.3 | Legal counsel, contracts & IP review — Y1 Q3 | 20d | 2027-03-01 | 2027-03-26 |  | K. Okonkwo; M. Bernstein; D. Flores [80%]; R. Thorne [20%] |
| 70 | 1.0.6.4 | Legal counsel, contracts & IP review — Y1 Q4 | 20d | 2027-06-01 | 2027-06-28 |  | N. Harris; S. Patel [90%]; D. Flores [80%]; R. Thorne [20%] |
| 71 | 1.0.6.5 | Legal counsel, contracts & IP review — Y2 Q1 | 20d | 2027-10-01 | 2027-10-28 |  | K. Okonkwo; M. Bernstein; D. Flores [80%]; R. Thorne [20%] |
| 72 | 1.0.6.6 | Legal counsel, contracts & IP review — Y2 Q2 | 20d | 2028-01-03 | 2028-01-28 |  | N. Harris; S. Patel [90%]; D. Flores [80%]; R. Thorne [20%] |
| 73 | 1.0.6.7 | Legal counsel, contracts & IP review — Y2 Q3 | 20d | 2028-04-03 | 2028-04-28 |  | K. Okonkwo; M. Bernstein; D. Flores [80%]; R. Thorne [20%] |
| 74 | 1.0.6.8 | Legal counsel, contracts & IP review — Y2 Q4 | 20d | 2028-07-03 | 2028-07-28 |  | N. Harris; S. Patel [90%]; D. Flores [80%]; R. Thorne [20%] |
| 75 | 1.0.6.9 | Legal counsel, contracts & IP review — Y3 Q1 | 20d | 2028-10-02 | 2028-10-27 |  | K. Okonkwo; M. Bernstein; D. Flores [80%]; R. Thorne [20%] |
| 76 | 1.0.6.10 | Legal counsel, contracts & IP review — Y3 Q2 | 20d | 2029-01-02 | 2029-01-29 |  | N. Harris; S. Patel [90%]; D. Flores [80%]; R. Thorne [20%] |
| 77 | 1.0.6.11 | Legal counsel, contracts & IP review — Y3 Q3 | 20d | 2029-04-02 | 2029-04-27 |  | K. Okonkwo; M. Bernstein; D. Flores [80%]; R. Thorne [20%] |
| 78 | 1.0.6.12 | Legal counsel, contracts & IP review — Y3 Q4 | 20d | 2029-07-02 | 2029-07-27 |  | N. Harris; S. Patel [90%]; D. Flores [80%]; R. Thorne [20%] |

| ID | WBS | Task | Duration | Start | Finish | Complete | Resources |
| --- | --- | --- | --- | --- | --- | --- | --- |
| 79 | 1.0.7 | **Compliance & Regulatory Assurance** | 759d | 2026-09-01 | 2029-07-27 | 4% |  |
| 80 | 1.0.7.1 | Compliance monitoring & regulatory liaison — Y1 Q1 | 20d | 2026-09-01 | 2026-09-28 | 45% | L. Huang; R. Kimani [90%]; C. Morrison [80%]; J. Martinez [30%] |
| 81 | 1.0.7.2 | Compliance monitoring & regulatory liaison — Y1 Q2 | 20d | 2026-12-01 | 2026-12-28 |  | T. Jackson; B. Cho [85%]; C. Morrison [80%]; U. Kowalski [80%] |
| 82 | 1.0.7.3 | Compliance monitoring & regulatory liaison — Y1 Q3 | 20d | 2027-03-01 | 2027-03-26 |  | L. Huang; R. Kimani [90%]; U. Kowalski [80%]; J. Martinez [30%] |
| 83 | 1.0.7.4 | Compliance monitoring & regulatory liaison — Y1 Q4 | 20d | 2027-06-01 | 2027-06-28 |  | T. Jackson; R. Kimani [90%]; B. Cho [85%]; C. Morrison [80%] |
| 84 | 1.0.7.5 | Compliance monitoring & regulatory liaison — Y2 Q1 | 20d | 2027-10-01 | 2027-10-28 |  | T. Jackson; L. Huang; U. Kowalski [80%]; J. Martinez [30%] |
| 85 | 1.0.7.6 | Compliance monitoring & regulatory liaison — Y2 Q2 | 20d | 2028-01-03 | 2028-01-28 |  | L. Huang; R. Kimani [90%]; B. Cho [85%]; C. Morrison [80%] |
| 86 | 1.0.7.7 | Compliance monitoring & regulatory liaison — Y2 Q3 | 20d | 2028-04-03 | 2028-04-28 |  | T. Jackson; B. Cho [85%]; U. Kowalski [80%]; J. Martinez [30%] |
| 87 | 1.0.7.8 | Compliance monitoring & regulatory liaison — Y2 Q4 | 20d | 2028-07-03 | 2028-07-28 |  | L. Huang; R. Kimani [90%]; C. Morrison [80%]; J. Martinez [30%] |
| 88 | 1.0.7.9 | Compliance monitoring & regulatory liaison — Y3 Q1 | 20d | 2028-10-02 | 2028-10-27 |  | T. Jackson; B. Cho [85%]; C. Morrison [80%]; U. Kowalski [80%] |
| 89 | 1.0.7.10 | Compliance monitoring & regulatory liaison — Y3 Q2 | 20d | 2029-01-02 | 2029-01-29 |  | L. Huang; R. Kimani [90%]; U. Kowalski [80%]; J. Martinez [30%] |
| 90 | 1.0.7.11 | Compliance monitoring & regulatory liaison — Y3 Q3 | 20d | 2029-04-02 | 2029-04-27 |  | T. Jackson; R. Kimani [90%]; B. Cho [85%]; C. Morrison [80%] |
| 91 | 1.0.7.12 | Compliance monitoring & regulatory liaison — Y3 Q4 | 20d | 2029-07-02 | 2029-07-27 |  | T. Jackson; L. Huang; U. Kowalski [80%]; J. Martinez [30%] |
| 92 | 1.0.8 | **SOX & Financial Controls Assurance** | 759d | 2026-09-01 | 2029-07-27 | 4% |  |
| 93 | 1.0.8.1 | SOX controls testing & audit support — Y1 Q1 | 20d | 2026-09-01 | 2026-09-28 | 45% | M. Osei; N. Brennan; O. Fairweather [90%]; K. Williams [25%] |
| 94 | 1.0.8.2 | SOX controls testing & audit support — Y1 Q2 | 20d | 2026-12-01 | 2026-12-28 |  | P. Whitcomb; O. Fairweather [90%]; Q. Marchetti [80%]; K. Williams [25%] |
| 95 | 1.0.8.3 | SOX controls testing & audit support — Y1 Q3 | 20d | 2027-03-01 | 2027-03-26 |  | M. Osei; N. Brennan; O. Fairweather [90%]; K. Williams [25%] |
| 96 | 1.0.8.4 | SOX controls testing & audit support — Y1 Q4 | 20d | 2027-06-01 | 2027-06-28 |  | P. Whitcomb; O. Fairweather [90%]; Q. Marchetti [80%]; K. Williams [25%] |
| 97 | 1.0.8.5 | SOX controls testing & audit support — Y2 Q1 | 20d | 2027-10-01 | 2027-10-28 |  | M. Osei; N. Brennan; O. Fairweather [90%]; K. Williams [25%] |
| 98 | 1.0.8.6 | SOX controls testing & audit support — Y2 Q2 | 20d | 2028-01-03 | 2028-01-28 |  | P. Whitcomb; O. Fairweather [90%]; Q. Marchetti [80%]; K. Williams [25%] |
| 99 | 1.0.8.7 | SOX controls testing & audit support — Y2 Q3 | 20d | 2028-04-03 | 2028-04-28 |  | M. Osei; N. Brennan; O. Fairweather [90%]; K. Williams [25%] |
| 100 | 1.0.8.8 | SOX controls testing & audit support — Y2 Q4 | 20d | 2028-07-03 | 2028-07-28 |  | P. Whitcomb; O. Fairweather [90%]; Q. Marchetti [80%]; K. Williams [25%] |
| 101 | 1.0.8.9 | SOX controls testing & audit support — Y3 Q1 | 20d | 2028-10-02 | 2028-10-27 |  | M. Osei; N. Brennan; O. Fairweather [90%]; K. Williams [25%] |
| 102 | 1.0.8.10 | SOX controls testing & audit support — Y3 Q2 | 20d | 2029-01-02 | 2029-01-29 |  | P. Whitcomb; O. Fairweather [90%]; Q. Marchetti [80%]; K. Williams [25%] |
| 103 | 1.0.8.11 | SOX controls testing & audit support — Y3 Q3 | 20d | 2029-04-02 | 2029-04-27 |  | M. Osei; N. Brennan; O. Fairweather [90%]; K. Williams [25%] |
| 104 | 1.0.8.12 | SOX controls testing & audit support — Y3 Q4 | 20d | 2029-07-02 | 2029-07-27 |  | P. Whitcomb; O. Fairweather [90%]; Q. Marchetti [80%]; K. Williams [25%] |

| ID | WBS | Task | Duration | Start | Finish | Predecessors | Complete | Resources |
| --- | --- | --- | --- | --- | --- | --- | --- | --- |
| 105 | 1.0.9 | **Workforce Planning & Org Design** | 564d | 2026-09-01 | 2028-10-27 |  | 15% |  |
| 106 | 1.0.9.1 | Workforce planning, ramp & retention — Year 1 | 20d | 2026-09-01 | 2026-09-28 |  | 45% | F. Bianchi; E. Marsh [90%]; G. Solberg [80%]; H. Rutherford [70%]; C. Johnson [20%] |
| 107 | 1.0.9.2 | Workforce planning, ramp & retention — Year 2 | 20d | 2027-10-01 | 2027-10-28 |  |  | D. Ferraro; F. Bianchi; E. Marsh [90%]; G. Solberg [80%]; C. Johnson [20%] |
| 108 | 1.0.9.3 | Workforce planning, ramp & retention — Year 3 | 20d | 2028-10-02 | 2028-10-27 |  |  | D. Ferraro; E. Marsh [90%]; G. Solberg [80%]; H. Rutherford [70%]; C. Johnson [20%] |
| 109 | 1.0.10 | **Vendor & SaaS Partner Management** | 564d | 2026-09-01 | 2028-10-27 |  | 15% |  |
| 110 | 1.0.10.1 | Vendor performance, SLA & renewal management — Year 1 | 20d | 2026-09-01 | 2026-09-28 |  | 45% | G. Ainsley; H. Prescott [90%]; L. Park [80%]; I. Merchant [80%] |
| 111 | 1.0.10.2 | Vendor performance, SLA & renewal management — Year 2 | 20d | 2027-10-01 | 2027-10-28 |  |  | G. Ainsley; H. Prescott [90%]; I. Merchant [80%]; L. Park [80%] |
| 112 | 1.0.10.3 | Vendor performance, SLA & renewal management — Year 3 | 20d | 2028-10-02 | 2028-10-27 |  |  | G. Ainsley; H. Prescott [90%]; I. Merchant [80%]; L. Park [80%] |
| 113 | 1.0.11 | **Program Communications** | 564d | 2026-09-01 | 2028-10-27 |  | 15% |  |
| 114 | 1.0.11.1 | Program communications & executive messaging — Year 1 | 20d | 2026-09-01 | 2026-09-28 |  | 45% | R. Castellanos [90%]; S. Halloway [80%]; T. Ainslie [70%]; B. Sullivan [30%] |
| 115 | 1.0.11.2 | Program communications & executive messaging — Year 2 | 20d | 2027-10-01 | 2027-10-28 |  |  | R. Castellanos [90%]; S. Halloway [80%]; T. Ainslie [70%]; B. Sullivan [30%] |
| 116 | 1.0.11.3 | Program communications & executive messaging — Year 3 | 20d | 2028-10-02 | 2028-10-27 |  |  | R. Castellanos [90%]; S. Halloway [80%]; T. Ainslie [70%]; B. Sullivan [30%] |
| 117 | 2.0 | **Data & Cloud AI Platform** | 759d | 2026-09-01 | 2029-07-27 |  | 4% |  |
| 118 | 2.0.1 | **Platform Architecture & Vendor Selection** | 43d | 2026-09-01 | 2026-10-29 |  | 21% |  |
| 119 | 2.0.1.1 | Platform requirements & reference architecture | 12d | 2026-09-01 | 2026-09-16 |  | 75% | W. Kumar; J. Restrepo; K. Vartan |
| 120 | 2.0.1.2 | **Cloud & AI platform vendor evaluation** | 15d | 2026-09-17 | 2026-10-07 |  |  |  |
| 121 | 2.0.1.2.1 | RFP issuance & vendor scoring | 7d | 2026-09-17 | 2026-09-25 | 119 |  | G. Ainsley; H. Prescott [90%] |
| 122 | 2.0.1.2.2 | Security & BAA review | 8d | 2026-09-28 | 2026-10-07 | 121 |  | N. Winthrop; O. Castillo; P. Halstead; Q. Beaumont; M. Hassan [20%] |
| 123 | 2.0.1.3 | Total cost & FinOps modelling | 8d | 2026-10-08 | 2026-10-19 | 120 |  | A. Rodriguez; B. Halvorsen |
| 124 | 2.0.1.4 | Vendor selection & contracting | 8d | 2026-10-20 | 2026-10-29 | 123 |  | H. Prescott [90%]; I. Merchant [80%] |
| 125 | 2.0.2 | **Cloud Foundation Build** | 54d | 2026-11-06 | 2027-01-20 |  |  |  |
| 126 | 2.0.2.1 | **Landing zone & network foundation** | 15d | 2026-11-06 | 2026-11-26 |  |  |  |
| 127 | 2.0.2.1.1 | Network & connectivity | 7d | 2026-11-06 | 2026-11-16 |  |  | A. Prescott; B. Fairweather; C. Sondheim; D. Marchetti; H. Nakamura [30%] |
| 128 | 2.0.2.1.2 | Core cloud services setup | 8d | 2026-11-17 | 2026-11-26 | 127 |  | D. Marchetti; E. Whitcomb; F. Talbot; G. Restrepo; H. Vartan |
| 129 | 2.0.2.2 | Identity & access management build | 10d | 2026-11-27 | 2026-12-10 | 126 |  | Q. Beaumont; R. Fontaine; S. Vasquez; T. Delvecchio; U. Kandel [90%] |
| 130 | 2.0.2.3 | Security controls & encryption baseline | 12d | 2026-12-11 | 2026-12-28 | 129 |  | N. Winthrop; O. Castillo; U. Kandel [90%]; V. Redmond [80%]; M. Hassan [20%] |
| 131 | 2.0.2.4 | Environment provisioning (dev/test/stage/prod) | 12d | 2026-12-29 | 2027-01-13 | 130 |  | H. Vartan; A. Prescott; B. Fairweather; I. Halvorsen [80%]; H. Nakamura [30%] |
| 132 | 2.0.2.5 | Platform Foundation go-live | 5d | 2027-01-14 | 2027-01-20 | 131 |  | K. Vartan; L. Sondheim; M. Marchetti |

| ID | WBS | Task | Duration | Start | Finish | Predecessors | Resources |
| --- | --- | --- | --- | --- | --- | --- | --- |
| 133 | 2.0.3 | **Data Lake & Governance Layer** | 90d | 2027-01-13 | 2027-05-18 |  |  |
| 134 | 2.0.3.1 | Data lake storage & zone design | 10d | 2027-01-13 | 2027-01-26 |  | M. Marchetti; N. Whitcomb; O. Talbot |
| 135 | 2.0.3.2 | Data cataloguing & metadata management | 12d | 2027-01-27 | 2027-02-11 | 134 | O. Talbot; P. Restrepo2; Q. Halvorsen2; R. Bianchi; S. Fitzgerald |
| 136 | 2.0.3.3 | Data lineage & quality framework | 12d | 2027-02-12 | 2027-03-01 | 135 | S. Fitzgerald; T. Andersen; U. Kowalczyk2 |
| 137 | 2.0.3.4 | Master data & reference data services | 10d | 2027-03-02 | 2027-03-15 | 136 | U. Kowalczyk2; V. Delvecchio2 |
| 138 | 2.0.3.5 | Data domain onboarding — claims | 12d | 2027-03-16 | 2027-03-31 | 137 | V. Delvecchio2; W. Solberg2; X. Nakashima2; Y. Winfield2; Z. Achebe2 |
| 139 | 2.0.3.6 | Data domain onboarding — member & provider | 12d | 2027-04-01 | 2027-04-16 | 138 | Z. Achebe2; W. Kumar; J. Restrepo; A. Larsen2 [90%]; B. Sorensen2 [90%] |
| 140 | 2.0.3.7 | Data domain onboarding — underwriting & risk | 12d | 2027-04-19 | 2027-05-04 | 139 | J. Restrepo; K. Vartan; L. Sondheim; M. Marchetti; N. Whitcomb |
| 141 | 2.0.3.8 | Privacy controls & PHI segregation | 10d | 2027-05-05 | 2027-05-18 | 140 | N. Achterberg; O. Whitlock; P. Sandoval [90%]; Q. Beckham [80%]; E. Sato [40%] |
| 142 | 2.0.4 | **MLOps Pipeline & Tooling** | 72d | 2027-03-22 | 2027-06-29 |  |  |
| 143 | 2.0.4.1 | **CI/CD pipeline for models & code** | 15d | 2027-03-22 | 2027-04-09 |  |  |
| 144 | 2.0.4.1.1 | Build & release automation | 7d | 2027-03-22 | 2027-03-30 |  | N. Whitcomb; O. Talbot; P. Restrepo2; Q. Halvorsen2; R. Bianchi |
| 145 | 2.0.4.1.2 | Automated test integration | 8d | 2027-03-31 | 2027-04-09 | 144 | R. Bianchi; S. Fitzgerald |
| 146 | 2.0.4.2 | Feature store implementation | 12d | 2027-04-12 | 2027-04-27 | 143 | S. Fitzgerald; T. Andersen; U. Kowalczyk2 |
| 147 | 2.0.4.3 | Model registry & versioning | 10d | 2027-04-28 | 2027-05-11 | 146 | U. Kowalczyk2; V. Delvecchio2 |
| 148 | 2.0.4.4 | Monitoring, drift detection & alerting | 15d | 2027-05-12 | 2027-06-01 | 147 | V. Delvecchio2; W. Solberg2; X. Nakashima2; Y. Winfield2; Z. Achebe2 |
| 149 | 2.0.4.5 | FinOps guardrails & cost telemetry | 10d | 2027-06-02 | 2027-06-15 | 148 | W. Kumar; J. Restrepo; K. Vartan |
| 150 | 2.0.4.6 | Platform security hardening & pen-test | 10d | 2027-06-16 | 2027-06-29 | 149 | O. Castillo; P. Halstead; Q. Beaumont; R. Fontaine; S. Vasquez |
| 151 | 2.0.5 | **Platform Scaling & Reliability** | 62d | 2027-05-27 | 2027-08-20 |  |  |
| 152 | 2.0.5.1 | Platform scaling for BRD-02/03 workloads | 20d | 2027-05-27 | 2027-06-23 |  | Z. Achebe2; W. Kumar; J. Restrepo; A. Larsen2 [90%]; B. Sorensen2 [90%] |
| 153 | 2.0.5.2 | High-availability & disaster-recovery build | 15d | 2027-06-24 | 2027-07-14 | 152 | B. Fairweather; C. Sondheim; D. Marchetti; E. Whitcomb; F. Talbot |
| 154 | 2.0.5.3 | Performance tuning & capacity management | 15d | 2027-07-15 | 2027-08-04 | 153 | F. Talbot; G. Restrepo; H. Vartan; I. Halvorsen [80%]; H. Nakamura [30%] |
| 155 | 2.0.5.4 | Observability & SRE practice rollout | 12d | 2027-08-05 | 2027-08-20 | 154 | A. Prescott; B. Fairweather; C. Sondheim; D. Marchetti; H. Nakamura [30%] |
| 156 | 2.0.6 | **Integration & API Services** | 54d | 2027-08-03 | 2027-10-15 |  |  |
| 157 | 2.0.6.1 | Enterprise integration layer build | 15d | 2027-08-03 | 2027-08-23 |  | J. Restrepo; K. Vartan; L. Sondheim; M. Marchetti; N. Whitcomb |
| 158 | 2.0.6.2 | API gateway & service mesh | 12d | 2027-08-24 | 2027-09-08 | 157 | D. Marchetti; E. Whitcomb; F. Talbot; G. Restrepo; H. Vartan |
| 159 | 2.0.6.3 | Event streaming & real-time services | 12d | 2027-09-09 | 2027-09-24 | 158 | N. Whitcomb; O. Talbot; P. Restrepo2; Q. Halvorsen2; R. Bianchi |
| 160 | 2.0.6.4 | Legacy system adapters | 15d | 2027-09-27 | 2027-10-15 | 159 | R. Bianchi; S. Fitzgerald; T. Andersen; U. Kowalczyk2; V. Delvecchio2 |

| ID | WBS | Task | Duration | Start | Finish | Predecessors | Complete | Resources |
| --- | --- | --- | --- | --- | --- | --- | --- | --- |
| 161 | 2.0.7 | **Data Quality & Stewardship** | 342d | 2027-10-08 | 2029-01-29 |  |  |  |
| 162 | 2.0.7.1 | Data quality rules engine | 12d | 2027-10-08 | 2027-10-25 |  |  | V. Delvecchio2; W. Solberg2; X. Nakashima2; Y. Winfield2; Z. Achebe2 |
| 163 | 2.0.7.2 | Data stewardship operating model | 10d | 2027-10-26 | 2027-11-08 | 162 |  | W. Kumar; J. Restrepo |
| 164 | 2.0.7.3 | Ongoing data quality monitoring — Year 2 | 20d | 2028-01-03 | 2028-01-28 |  |  | Z. Achebe2; W. Kumar; J. Restrepo; A. Larsen2 [90%]; B. Sorensen2 [90%] |
| 165 | 2.0.7.4 | Ongoing data quality monitoring — Year 3 | 20d | 2029-01-02 | 2029-01-29 |  |  | J. Restrepo; K. Vartan; L. Sondheim; M. Marchetti; N. Whitcomb |
| 166 | 2.0.8 | **Platform Operations (Run)** | 759d | 2026-09-01 | 2029-07-27 |  | 4% |  |
| 167 | 2.0.8.1 | Platform run, patching & support — Y1 Q1 | 20d | 2026-09-01 | 2026-09-28 |  | 45% | H. Vartan; A. Prescott; B. Fairweather; I. Halvorsen [80%]; H. Nakamura [30%] |
| 168 | 2.0.8.2 | Platform run, patching & support — Y1 Q2 | 20d | 2026-12-01 | 2026-12-28 |  |  | B. Fairweather; C. Sondheim; D. Marchetti; E. Whitcomb; F. Talbot |
| 169 | 2.0.8.3 | Platform run, patching & support — Y1 Q3 | 20d | 2027-03-01 | 2027-03-26 |  |  | F. Talbot; G. Restrepo; H. Vartan; I. Halvorsen [80%]; H. Nakamura [30%] |
| 170 | 2.0.8.4 | Platform run, patching & support — Y1 Q4 | 20d | 2027-06-01 | 2027-06-28 |  |  | A. Prescott; B. Fairweather; C. Sondheim; D. Marchetti; H. Nakamura [30%] |
| 171 | 2.0.8.5 | Platform run, patching & support — Y2 Q1 | 20d | 2027-10-01 | 2027-10-28 |  |  | D. Marchetti; E. Whitcomb; F. Talbot; G. Restrepo; H. Vartan |
| 172 | 2.0.8.6 | Platform run, patching & support — Y2 Q2 | 20d | 2028-01-03 | 2028-01-28 |  |  | H. Vartan; A. Prescott; B. Fairweather; I. Halvorsen [80%]; H. Nakamura [30%] |
| 173 | 2.0.8.7 | Platform run, patching & support — Y2 Q3 | 20d | 2028-04-03 | 2028-04-28 |  |  | B. Fairweather; C. Sondheim; D. Marchetti; E. Whitcomb; F. Talbot |
| 174 | 2.0.8.8 | Platform run, patching & support — Y2 Q4 | 20d | 2028-07-03 | 2028-07-28 |  |  | F. Talbot; G. Restrepo; H. Vartan; I. Halvorsen [80%]; H. Nakamura [30%] |
| 175 | 2.0.8.9 | Platform run, patching & support — Y3 Q1 | 20d | 2028-10-02 | 2028-10-27 |  |  | A. Prescott; B. Fairweather; C. Sondheim; D. Marchetti; H. Nakamura [30%] |
| 176 | 2.0.8.10 | Platform run, patching & support — Y3 Q2 | 20d | 2029-01-02 | 2029-01-29 |  |  | D. Marchetti; E. Whitcomb; F. Talbot; G. Restrepo; H. Vartan |
| 177 | 2.0.8.11 | Platform run, patching & support — Y3 Q3 | 20d | 2029-04-02 | 2029-04-27 |  |  | H. Vartan; A. Prescott; B. Fairweather; I. Halvorsen [80%]; H. Nakamura [30%] |
| 178 | 2.0.8.12 | Platform run, patching & support — Y3 Q4 | 20d | 2029-07-02 | 2029-07-27 |  |  | B. Fairweather; C. Sondheim; D. Marchetti; E. Whitcomb; F. Talbot |
| 179 | 2.0.9 | **Service Desk & Production Support** | 564d | 2026-09-01 | 2028-10-27 |  | 15% |  |
| 180 | 2.0.9.1 | AI service desk & production support — Year 1 | 20d | 2026-09-01 | 2026-09-28 |  | 45% | N. Alvarado4; O. Whitby7; P. Okoro7; Q. Beaumont5; M. Washington (CustOps) [20%] |
| 181 | 2.0.9.2 | AI service desk & production support — Year 2 | 20d | 2027-10-01 | 2027-10-28 |  |  | Q. Beaumont5; S. Delvecchio6; T. Solberg6; R. Kowalczyk6 [90%]; U. Nakashima6 [80%] |
| 182 | 2.0.9.3 | AI service desk & production support — Year 3 | 20d | 2028-10-02 | 2028-10-27 |  |  | X. Larsen6; U. Nakashima6 [80%]; V. Winfield6 [80%]; W. Achebe6 [70%]; M. Washington (CustOps) [20%] |
| 183 | 2.0.10 | **Infrastructure & Cloud Cost Management** | 564d | 2026-09-01 | 2028-10-27 |  | 15% |  |
| 184 | 2.0.10.1 | Cloud cost optimization & FinOps review — Year 1 | 20d | 2026-09-01 | 2026-09-28 |  | 45% | K. Vartan; L. Sondheim |
| 185 | 2.0.10.2 | Cloud cost optimization & FinOps review — Year 2 | 20d | 2027-10-01 | 2027-10-28 |  |  | L. Sondheim; M. Marchetti |
| 186 | 2.0.10.3 | Cloud cost optimization & FinOps review — Year 3 | 20d | 2028-10-02 | 2028-10-27 |  |  | M. Marchetti; N. Whitcomb |

| ID | WBS | Task | Duration | Start | Finish | Predecessors | Complete | Resources |
| --- | --- | --- | --- | --- | --- | --- | --- | --- |
| 187 | 2.0.11 | **Steady-State Transition** | 39d | 2028-07-04 | 2028-08-25 |  |  |  |
| 188 | 2.0.11.1 | Operations runbook & knowledge base | 12d | 2028-07-04 | 2028-07-19 |  |  | F. Talbot; G. Restrepo; H. Vartan; I. Halvorsen [80%]; H. Nakamura [30%] |
| 189 | 2.0.11.2 | Platform handover to ACME operations | 15d | 2028-07-20 | 2028-08-09 | 188 |  | N. Whitcomb; O. Talbot; P. Restrepo2 |
| 190 | 2.0.11.3 | Post-transition support & assurance | 12d | 2028-08-10 | 2028-08-25 | 189 |  | A. Prescott; H. Nakamura [30%] |
| 191 | 3.0 | **AI Governance & Center of Excellence** | 765d | 2026-08-24 | 2029-07-27 |  | 6% |  |
| 192 | 3.0.1 | **CoE Charter & Operating Model** | 35d | 2026-08-24 | 2026-10-09 |  | 43% |  |
| 193 | 3.0.1.1 | AI Center of Excellence charter | 8d | 2026-08-24 | 2026-09-02 |  | 100% | S. Khurana; A. Reyes; J. Ferraro |
| 194 | 3.0.1.2 | Hub-and-spoke operating model design | 8d | 2026-09-03 | 2026-09-14 | 193 | 88% | J. Ferraro; M. Delacroix |
| 195 | 3.0.1.3 | CoE role definition & staffing model | 7d | 2026-09-15 | 2026-09-23 | 194 |  | S. Khurana; A. Reyes |
| 196 | 3.0.1.4 | **AI Readiness Assessment** | 12d | 2026-09-24 | 2026-10-09 |  |  |  |
| 197 | 3.0.1.4.1 | Capability & data readiness review | 6d | 2026-09-24 | 2026-10-01 | 195 |  | M. Delacroix; C. Alvarez; T. Nakamura; R. Osei; P. Singh [90%] |
| 198 | 3.0.1.4.2 | Readiness report & roadmap | 6d | 2026-10-02 | 2026-10-09 | 197 |  | R. Osei; V. Castellano |
| 199 | 3.0.2 | **Governance Framework (NIST AI RMF / ISO 42001)** | 63d | 2026-11-13 | 2027-02-09 |  |  |  |
| 200 | 3.0.2.1 | AI governance framework v1 | 12d | 2026-11-13 | 2026-11-30 |  |  | V. Castellano; L. Whitfield; K. Novak [80%] |
| 201 | 3.0.2.2 | Responsible-AI standards & policies | 10d | 2026-12-01 | 2026-12-14 | 200 |  | D. Ibrahim; S. Khurana; A. Reyes; J. Ferraro; K. Novak [80%] |
| 202 | 3.0.2.3 | Model risk management & two-line-of-defense process | 10d | 2026-12-15 | 2026-12-28 | 201 |  | S. Khurana; A. Reyes; J. Ferraro |
| 203 | 3.0.2.4 | AI Governance Board & EARB stand-up | 6d | 2026-12-29 | 2027-01-05 | 202 |  | J. Ferraro; M. Delacroix |
| 204 | 3.0.2.5 | Model-card standards & registry governance | 10d | 2027-01-06 | 2027-01-19 | 203 |  | M. Delacroix; P. Singh [90%] |
| 205 | 3.0.2.6 | AI use-case intake & triage process | 8d | 2027-01-20 | 2027-01-29 | 204 |  | C. Alvarez; P. Singh [90%] |
| 206 | 3.0.2.7 | Ethics review & escalation protocol | 7d | 2027-02-01 | 2027-02-09 | 205 |  | C. Alvarez; T. Nakamura |
| 207 | 3.0.3 | **Governance Board Operations** | 759d | 2026-09-01 | 2029-07-27 |  | 4% |  |
| 208 | 3.0.3.1 | AI Governance Board & EARB operations — Y1 Q1 | 20d | 2026-09-01 | 2026-09-28 |  | 45% | T. Nakamura; R. Osei; V. Castellano; L. Whitfield; K. Novak [80%] |
| 209 | 3.0.3.2 | AI Governance Board & EARB operations — Y1 Q2 | 20d | 2026-12-01 | 2026-12-28 |  |  | D. Ibrahim; S. Khurana; A. Reyes; J. Ferraro; K. Novak [80%] |
| 210 | 3.0.3.3 | AI Governance Board & EARB operations — Y1 Q3 | 20d | 2027-03-01 | 2027-03-26 |  |  | J. Ferraro; M. Delacroix; C. Alvarez; T. Nakamura; P. Singh [90%] |
| 211 | 3.0.3.4 | AI Governance Board & EARB operations — Y1 Q4 | 20d | 2027-06-01 | 2027-06-28 |  |  | T. Nakamura; R. Osei; V. Castellano; L. Whitfield; K. Novak [80%] |
| 212 | 3.0.3.5 | AI Governance Board & EARB operations — Y2 Q1 | 20d | 2027-10-01 | 2027-10-28 |  |  | D. Ibrahim; S. Khurana; A. Reyes; J. Ferraro; K. Novak [80%] |
| 213 | 3.0.3.6 | AI Governance Board & EARB operations — Y2 Q2 | 20d | 2028-01-03 | 2028-01-28 |  |  | J. Ferraro; M. Delacroix; C. Alvarez; T. Nakamura; P. Singh [90%] |
| 214 | 3.0.3.7 | AI Governance Board & EARB operations — Y2 Q3 | 20d | 2028-04-03 | 2028-04-28 |  |  | T. Nakamura; R. Osei; V. Castellano; L. Whitfield; K. Novak [80%] |
| 215 | 3.0.3.8 | AI Governance Board & EARB operations — Y2 Q4 | 20d | 2028-07-03 | 2028-07-28 |  |  | D. Ibrahim; S. Khurana; A. Reyes; J. Ferraro; K. Novak [80%] |
| 216 | 3.0.3.9 | AI Governance Board & EARB operations — Y3 Q1 | 20d | 2028-10-02 | 2028-10-27 |  |  | J. Ferraro; M. Delacroix; C. Alvarez; T. Nakamura; P. Singh [90%] |
| 217 | 3.0.3.10 | AI Governance Board & EARB operations — Y3 Q2 | 20d | 2029-01-02 | 2029-01-29 |  |  | T. Nakamura; R. Osei; V. Castellano; L. Whitfield; K. Novak [80%] |
| 218 | 3.0.3.11 | AI Governance Board & EARB operations — Y3 Q3 | 20d | 2029-04-02 | 2029-04-27 |  |  | D. Ibrahim; S. Khurana; A. Reyes; J. Ferraro; K. Novak [80%] |
| 219 | 3.0.3.12 | AI Governance Board & EARB operations — Y3 Q4 | 20d | 2029-07-02 | 2029-07-27 |  |  | J. Ferraro; M. Delacroix; C. Alvarez; T. Nakamura; P. Singh [90%] |

| ID | WBS | Task | Duration | Start | Finish | Complete | Resources |
| --- | --- | --- | --- | --- | --- | --- | --- |
| 220 | 3.0.4 | **Enterprise Architecture Governance** | 759d | 2026-09-01 | 2029-07-27 | 4% |  |
| 221 | 3.0.4.1 | Architecture review, standards & roadmap governance — Y1 Q1 | 20d | 2026-09-01 | 2026-09-28 | 45% | F. Okonkwo; G. Petrova; H. Delgado; I. Suzuki; D. Chen [25%] |
| 222 | 3.0.4.2 | Architecture review, standards & roadmap governance — Y1 Q2 | 20d | 2026-12-01 | 2026-12-28 |  | I. Suzuki; J. Kowalczyk; L. Fitzgerald; K. Andersen [80%]; D. Chen [25%] |
| 223 | 3.0.4.3 | Architecture review, standards & roadmap governance — Y1 Q3 | 20d | 2027-03-01 | 2027-03-26 |  | F. Okonkwo; G. Petrova; H. Delgado; I. Suzuki; D. Chen [25%] |
| 224 | 3.0.4.4 | Architecture review, standards & roadmap governance — Y1 Q4 | 20d | 2027-06-01 | 2027-06-28 |  | I. Suzuki; J. Kowalczyk; L. Fitzgerald; K. Andersen [80%]; D. Chen [25%] |
| 225 | 3.0.4.5 | Architecture review, standards & roadmap governance — Y2 Q1 | 20d | 2027-10-01 | 2027-10-28 |  | F. Okonkwo; G. Petrova; H. Delgado; I. Suzuki; D. Chen [25%] |
| 226 | 3.0.4.6 | Architecture review, standards & roadmap governance — Y2 Q2 | 20d | 2028-01-03 | 2028-01-28 |  | I. Suzuki; J. Kowalczyk; L. Fitzgerald; K. Andersen [80%]; D. Chen [25%] |
| 227 | 3.0.4.7 | Architecture review, standards & roadmap governance — Y2 Q3 | 20d | 2028-04-03 | 2028-04-28 |  | F. Okonkwo; G. Petrova; H. Delgado; I. Suzuki; D. Chen [25%] |
| 228 | 3.0.4.8 | Architecture review, standards & roadmap governance — Y2 Q4 | 20d | 2028-07-03 | 2028-07-28 |  | I. Suzuki; J. Kowalczyk; L. Fitzgerald; K. Andersen [80%]; D. Chen [25%] |
| 229 | 3.0.4.9 | Architecture review, standards & roadmap governance — Y3 Q1 | 20d | 2028-10-02 | 2028-10-27 |  | F. Okonkwo; G. Petrova; H. Delgado; I. Suzuki; D. Chen [25%] |
| 230 | 3.0.4.10 | Architecture review, standards & roadmap governance — Y3 Q2 | 20d | 2029-01-02 | 2029-01-29 |  | I. Suzuki; J. Kowalczyk; L. Fitzgerald; K. Andersen [80%]; D. Chen [25%] |
| 231 | 3.0.4.11 | Architecture review, standards & roadmap governance — Y3 Q3 | 20d | 2029-04-02 | 2029-04-27 |  | F. Okonkwo; G. Petrova; H. Delgado; I. Suzuki; D. Chen [25%] |
| 232 | 3.0.4.12 | Architecture review, standards & roadmap governance — Y3 Q4 | 20d | 2029-07-02 | 2029-07-27 |  | I. Suzuki; J. Kowalczyk; L. Fitzgerald; K. Andersen [80%]; D. Chen [25%] |
| 233 | 3.0.5 | **Security & Privacy Assurance** | 759d | 2026-09-01 | 2029-07-27 | 4% |  |
| 234 | 3.0.5.1 | Security architecture review & privacy assurance — Y1 Q1 | 20d | 2026-09-01 | 2026-09-28 | 45% | N. Winthrop; O. Castillo; P. Halstead; Q. Beaumont; M. Hassan [20%] |
| 235 | 3.0.5.2 | Security architecture review & privacy assurance — Y1 Q2 | 20d | 2026-12-01 | 2026-12-28 |  | Q. Beaumont; R. Fontaine; S. Vasquez; T. Delvecchio; U. Kandel [90%] |
| 236 | 3.0.5.3 | Security architecture review & privacy assurance — Y1 Q3 | 20d | 2027-03-01 | 2027-03-26 |  | N. Achterberg; O. Whitlock; U. Kandel [90%]; V. Redmond [80%]; E. Sato [40%] |
| 237 | 3.0.5.4 | Security architecture review & privacy assurance — Y1 Q4 | 20d | 2027-06-01 | 2027-06-28 |  | O. Whitlock; N. Winthrop; P. Sandoval [90%]; Q. Beckham [80%]; M. Hassan [20%] |
| 238 | 3.0.5.5 | Security architecture review & privacy assurance — Y2 Q1 | 20d | 2027-10-01 | 2027-10-28 |  | N. Winthrop; O. Castillo; P. Halstead; Q. Beaumont; R. Fontaine |
| 239 | 3.0.5.6 | Security architecture review & privacy assurance — Y2 Q2 | 20d | 2028-01-03 | 2028-01-28 |  | R. Fontaine; S. Vasquez; T. Delvecchio; U. Kandel [90%]; V. Redmond [80%] |
| 240 | 3.0.5.7 | Security architecture review & privacy assurance — Y2 Q3 | 20d | 2028-04-03 | 2028-04-28 |  | N. Achterberg; O. Whitlock; P. Sandoval [90%]; V. Redmond [80%]; E. Sato [40%] |
| 241 | 3.0.5.8 | Security architecture review & privacy assurance — Y2 Q4 | 20d | 2028-07-03 | 2028-07-28 |  | N. Winthrop; O. Castillo; P. Sandoval [90%]; Q. Beckham [80%]; M. Hassan [20%] |
| 242 | 3.0.5.9 | Security architecture review & privacy assurance — Y3 Q1 | 20d | 2028-10-02 | 2028-10-27 |  | O. Castillo; P. Halstead; Q. Beaumont; R. Fontaine; S. Vasquez |
| 243 | 3.0.5.10 | Security architecture review & privacy assurance — Y3 Q2 | 20d | 2029-01-02 | 2029-01-29 |  | S. Vasquez; T. Delvecchio; U. Kandel [90%]; V. Redmond [80%]; E. Sato [40%] |
| 244 | 3.0.5.11 | Security architecture review & privacy assurance — Y3 Q3 | 20d | 2029-04-02 | 2029-04-27 |  | N. Achterberg; O. Whitlock; P. Sandoval [90%]; Q. Beckham [80%]; E. Sato [40%] |
| 245 | 3.0.5.12 | Security architecture review & privacy assurance — Y3 Q4 | 20d | 2029-07-02 | 2029-07-27 |  | N. Winthrop; O. Castillo; P. Halstead; Q. Beckham [80%]; M. Hassan [20%] |

| ID | WBS | Task | Duration | Start | Finish | Predecessors | Complete | Resources |
| --- | --- | --- | --- | --- | --- | --- | --- | --- |
| 246 | 3.0.6 | **Independent Model Validation Practice** | 363d | 2027-10-11 | 2029-02-28 |  |  |  |
| 247 | 3.0.6.1 | IMV methodology & standards | 10d | 2027-10-11 | 2027-10-22 |  |  | P. Okafor; W. Achebe; X. Sorensen |
| 248 | 3.0.6.2 | Validation tooling & test harness | 10d | 2027-10-25 | 2027-11-05 | 247 |  | X. Sorensen; Y. Larsen |
| 249 | 3.0.6.3 | IMV capacity planning & queue management | 8d | 2027-11-08 | 2027-11-17 | 248 |  | Y. Larsen; Z. Winfield (IMV) |
| 250 | 3.0.6.4 | Annual model re-validation cycle — Year 2 | 20d | 2028-02-01 | 2028-02-28 |  |  | Z. Winfield (IMV); P. Okafor; W. Achebe; X. Sorensen; A. Kessler [90%] |
| 251 | 3.0.6.5 | Annual model re-validation cycle — Year 3 | 20d | 2029-02-01 | 2029-02-28 |  |  | X. Sorensen; Y. Larsen; Z. Winfield (IMV); P. Okafor; A. Kessler [90%] |
| 252 | 3.0.7 | **Regulatory & Policy Monitoring** | 564d | 2026-09-01 | 2028-10-27 |  | 15% |  |
| 253 | 3.0.7.1 | Regulatory horizon scanning (NAIC / state AI law) — Year 1 | 20d | 2026-09-01 | 2026-09-28 |  | 45% | K. Okonkwo; M. Bernstein; D. Flores [80%]; R. Thorne [20%] |
| 254 | 3.0.7.2 | Regulatory horizon scanning (NAIC / state AI law) — Year 2 | 20d | 2027-10-01 | 2027-10-28 |  |  | N. Harris; S. Patel [90%]; D. Flores [80%]; J. Martinez [30%] |
| 255 | 3.0.7.3 | Regulatory horizon scanning (NAIC / state AI law) — Year 3 | 20d | 2028-10-02 | 2028-10-27 |  |  | L. Huang; R. Kimani [90%]; C. Morrison [80%]; J. Martinez [30%] |
| 256 | 3.0.8 | **AI Literacy & Enablement** | 47d | 2028-03-23 | 2028-05-26 |  |  |  |
| 257 | 3.0.8.1 | AI literacy curriculum for business stakeholders | 12d | 2028-03-23 | 2028-04-07 |  |  | S. Khurana; A. Reyes; J. Ferraro |
| 258 | 3.0.8.2 | Responsible-AI training rollout | 15d | 2028-04-10 | 2028-04-28 | 257 |  | G. Okonkwo; B. Prescott; C. Whitfield; D. Solis; E. Winthrop [90%] |
| 259 | 3.0.8.3 | CoE community of practice & office hours | 20d | 2028-05-01 | 2028-05-26 | 258 |  | T. Nakamura; R. Osei; V. Castellano; L. Whitfield; K. Novak [80%] |
| 260 | 3.0.9 | **Governance Audit & Assurance** | 564d | 2026-09-01 | 2028-10-27 |  | 15% |  |
| 261 | 3.0.9.1 | Internal AI governance audit & remediation — Year 1 | 20d | 2026-09-01 | 2026-09-28 |  | 45% | L. Huang; R. Kimani [90%]; C. Morrison [80%]; J. Martinez [30%] |
| 262 | 3.0.9.2 | Internal AI governance audit & remediation — Year 2 | 20d | 2027-10-01 | 2027-10-28 |  |  | T. Jackson; B. Cho [85%]; C. Morrison [80%]; U. Kowalski [80%] |
| 263 | 3.0.9.3 | Internal AI governance audit & remediation — Year 3 | 20d | 2028-10-02 | 2028-10-27 |  |  | S. Khurana; A. Reyes; J. Ferraro; U. Kowalski [80%] |
| 264 | 4.0 | **BRD-01 · Claims & Prior Authorization AI** | 216d | 2026-10-05 | 2027-08-02 |  |  |  |
| 265 | 4.0.1 | **Requirements & JAD** | 61d | 2026-10-05 | 2026-12-28 |  |  |  |
| 266 | 4.0.1.1 | **Requirements elicitation workshops (JAD series)** | 17d | 2026-10-05 | 2026-10-27 |  |  |  |
| 267 | 4.0.1.1.1 | Current-state process mapping | 6d | 2026-10-05 | 2026-10-12 |  |  | F. Bennett; C. Garcia2 |
| 268 | 4.0.1.1.2 | Use-case & user-story definition | 6d | 2026-10-13 | 2026-10-20 | 267 |  | C. Garcia2; D. Thompson2; E. Washington2; F. Ferraro2; G. Delacroix2 |
| 269 | 4.0.1.1.3 | Non-functional & compliance requirements | 5d | 2026-10-21 | 2026-10-27 | 268 |  | F. Bennett; C. Garcia2 |

| ID | WBS | Task | Duration | Start | Finish | Predecessors | Resources |
| --- | --- | --- | --- | --- | --- | --- | --- |
| 270 | 4.0.1.2 | **Data & source-system requirements** | 8d | 2026-10-28 | 2026-11-06 |  |  |
| 271 | 4.0.1.2.1 | Source-system inventory | 4d | 2026-10-28 | 2026-11-02 | 266 | P. Restrepo2; Q. Halvorsen2 |
| 272 | 4.0.1.2.2 | Data availability & quality requirements | 4d | 2026-11-03 | 2026-11-06 | 271 | Q. Halvorsen2; R. Bianchi |
| 273 | 4.0.1.3 | Model & decision-logic requirements | 8d | 2026-11-09 | 2026-11-18 | 270 | G. Delacroix2; H. Vartan2 |
| 274 | 4.0.1.4 | Business rules & policy catalogue | 7d | 2026-11-19 | 2026-11-27 | 273 | F. Bennett; C. Garcia2 |
| 275 | 4.0.1.5 | Clinical / actuarial SME requirements review | 6d | 2026-11-30 | 2026-12-07 | 274 | K. Okoro; L. Delacroix [90%]; Dr. J. Whitby [80%]; Dr. I. Alvarado [50%]; Dr. N. Patel [25%] |
| 276 | 4.0.1.6 | Requirements traceability matrix baseline | 5d | 2026-12-08 | 2026-12-14 | 275 | H. Vartan2; I. Halvorsen2 |
| 277 | 4.0.1.7 | Requirements review & BRD authoring | 7d | 2026-12-15 | 2026-12-23 | 276 | I. Halvorsen2; J. Nakamura2 |
| 278 | 4.0.1.8 | BRD sign-off (JAD close, AI Governance Board) | 3d | 2026-12-24 | 2026-12-28 | 277 | J. Nakamura2; K. Okoro2 |
| 279 | 4.0.2 | **Architecture & Design** | 57d | 2026-10-21 | 2027-01-07 |  |  |
| 280 | 4.0.2.1 | **Solution architecture & integration design** | 12d | 2026-10-21 | 2026-11-05 |  |  |
| 281 | 4.0.2.1.1 | Target-state architecture | 6d | 2026-10-21 | 2026-10-28 |  | F. Okonkwo; D. Chen [25%] |
| 282 | 4.0.2.1.2 | Integration & API design | 6d | 2026-10-29 | 2026-11-05 | 281 | F. Okonkwo; G. Petrova |
| 283 | 4.0.2.2 | Data architecture & pipeline design | 10d | 2026-11-06 | 2026-11-19 | 280 | R. Bianchi; S. Fitzgerald |
| 284 | 4.0.2.3 | **Model design & approach selection** | 10d | 2026-11-20 | 2026-12-03 |  |  |
| 285 | 4.0.2.3.1 | Model approach evaluation | 5d | 2026-11-20 | 2026-11-26 | 283 | K. Okoro2; L. Whitby2 |
| 286 | 4.0.2.3.2 | Model design specification | 5d | 2026-11-27 | 2026-12-03 | 285 | L. Whitby2; M. Beaumont2 |
| 287 | 4.0.2.4 | Security threat model & controls design | 8d | 2026-12-04 | 2026-12-15 | 284 | S. Vasquez; T. Delvecchio; U. Kandel [90%]; V. Redmond [80%]; M. Hassan [20%] |
| 288 | 4.0.2.5 | Privacy-by-design & PHI data-flow review | 6d | 2026-12-16 | 2026-12-23 | 287 | Q. Beckham [80%]; E. Sato [40%] |
| 289 | 4.0.2.6 | Infrastructure & environment design | 7d | 2026-12-24 | 2027-01-01 | 288 | A. Prescott; B. Fairweather |
| 290 | 4.0.2.7 | Design review & EARB approval | 4d | 2027-01-04 | 2027-01-07 | 289 | G. Petrova; H. Delgado |
| 291 | 4.0.3 | **Experience & Interaction Design** | 64d | 2026-11-06 | 2027-02-03 |  |  |
| 292 | 4.0.3.1 | User research & journey mapping | 10d | 2026-11-06 | 2026-11-19 |  | J. Lee; U. Marchetti; V. Okwuosa; W. Pham; X. Delgado |
| 293 | 4.0.3.2 | Information architecture & wireframes | 12d | 2026-11-20 | 2026-12-07 | 292 | X. Delgado; Y. Nakashima (UX); J. Lee; Z. Fairbanks [90%]; A. Castillo [80%] |
| 294 | 4.0.3.3 | Design system & component library | 12d | 2026-12-08 | 2026-12-23 | 293 | J. Lee; U. Marchetti; V. Okwuosa; W. Pham; X. Delgado |
| 295 | 4.0.3.4 | Conversational / interaction design | 10d | 2026-12-24 | 2027-01-06 | 294 | X. Delgado; Y. Nakashima (UX); J. Lee; Z. Fairbanks [90%]; A. Castillo [80%] |
| 296 | 4.0.3.5 | Accessibility & WCAG compliance review | 8d | 2027-01-07 | 2027-01-18 | 295 | J. Lee; U. Marchetti; V. Okwuosa; W. Pham; X. Delgado |

| ID | WBS | Task | Duration | Start | Finish | Predecessors | Resources |
| --- | --- | --- | --- | --- | --- | --- | --- |
| 297 | 4.0.3.6 | **Usability testing & design iteration** | 12d | 2027-01-19 | 2027-02-03 |  |  |
| 298 | 4.0.3.6.1 | Usability test sessions | 6d | 2027-01-19 | 2027-01-26 | 296 | X. Delgado; Y. Nakashima (UX); J. Lee; Z. Fairbanks [90%]; A. Castillo [80%] |
| 299 | 4.0.3.6.2 | Design refinement from findings | 6d | 2027-01-27 | 2027-02-03 | 298 | J. Lee; U. Marchetti; V. Okwuosa; W. Pham; X. Delgado |
| 300 | 4.0.4 | **Clinical / Business Policy Alignment** | 36d | 2026-11-24 | 2027-01-12 |  |  |
| 301 | 4.0.4.1 | Clinical policy & medical necessity criteria review | 10d | 2026-11-24 | 2026-12-07 |  | L. Delacroix [90%]; M. Beaumont [80%]; Dr. J. Whitby [80%]; Dr. I. Alvarado [50%]; Dr. N. Patel [25%] |
| 302 | 4.0.4.2 | Decision-logic clinical validation | 10d | 2026-12-08 | 2026-12-21 | 301 | K. Okoro; L. Delacroix [90%]; Dr. J. Whitby [80%]; M. Beaumont [80%]; Dr. N. Patel [25%] |
| 303 | 4.0.4.3 | Provider & utilization-management impact review | 8d | 2026-12-22 | 2026-12-31 | 302 | K. Okoro; L. Delacroix [90%]; Dr. J. Whitby [80%]; Dr. I. Alvarado [50%]; Dr. N. Patel [25%] |
| 304 | 4.0.4.4 | Policy exception & appeals handling design | 8d | 2027-01-01 | 2027-01-12 | 303 | Dr. J. Whitby [80%]; Dr. I. Alvarado [50%]; Dr. N. Patel [25%] |
| 305 | 4.0.5 | **Data Engineering & Feature Prep** | 61d | 2026-12-10 | 2027-03-04 |  |  |
| 306 | 4.0.5.1 | **Data profiling & quality assessment** | 12d | 2026-12-10 | 2026-12-25 |  |  |
| 307 | 4.0.5.1.1 | Legacy source profiling | 6d | 2026-12-10 | 2026-12-17 |  | S. Fitzgerald; T. Andersen; U. Kowalczyk2; V. Delvecchio2; W. Solberg2 |
| 308 | 4.0.5.1.2 | Data quality scorecard & remediation plan | 6d | 2026-12-18 | 2026-12-25 | 307 | W. Solberg2; X. Nakashima2 |
| 309 | 4.0.5.2 | **Data ingestion & pipeline build** | 15d | 2026-12-28 | 2027-01-15 |  |  |
| 310 | 4.0.5.2.1 | Source connectors & ingestion | 7d | 2026-12-28 | 2027-01-05 | 306 | X. Nakashima2; Y. Winfield2; Z. Achebe2; A. Larsen2 [90%]; B. Sorensen2 [90%] |
| 311 | 4.0.5.2.2 | Transformation & cleansing rules | 8d | 2027-01-06 | 2027-01-15 | 310 | W. Kumar; B. Sorensen2 [90%] |
| 312 | 4.0.5.3 | Data remediation execution | 12d | 2027-01-18 | 2027-02-02 | 309 | W. Kumar; J. Restrepo; K. Vartan; L. Sondheim; M. Marchetti |
| 313 | 4.0.5.4 | Feature engineering & dataset assembly | 12d | 2027-02-03 | 2027-02-18 | 312 | F. Bennett; C. Garcia2; D. Thompson2 |
| 314 | 4.0.5.5 | Data privacy & PHI controls validation | 6d | 2027-02-19 | 2027-02-26 | 313 | N. Achterberg; E. Sato [40%] |
| 315 | 4.0.5.6 | Training / test dataset governance sign-off | 4d | 2027-03-01 | 2027-03-04 | 314 | D. Ibrahim; K. Novak [80%] |
| 316 | 4.0.6 | **Model Development & Training** | 64d | 2026-12-28 | 2027-03-25 |  |  |
| 317 | 4.0.6.1 | Baseline model build | 15d | 2026-12-28 | 2027-01-15 |  | M. Beaumont2; N. Kowalczyk3; O. Delvecchio3 |
| 318 | 4.0.6.2 | **Model training & iteration cycles** | 22d | 2027-01-18 | 2027-02-16 |  |  |
| 319 | 4.0.6.2.1 | Training run cycle 1 | 6d | 2027-01-18 | 2027-01-25 | 317 | O. Delvecchio3; P. Solberg3; Q. Nakashima3; R. Winfield3; S. Achebe3 |
| 320 | 4.0.6.2.2 | Evaluation & error analysis | 5d | 2027-01-26 | 2027-02-01 | 319 | S. Achebe3; T. Larsen3 |
| 321 | 4.0.6.2.3 | Training run cycle 2 (tuned) | 6d | 2027-02-02 | 2027-02-09 | 320 | T. Larsen3; U. Sorensen3; V. Kessler2; W. Rutherford2; X. Alvarado2 |
| 322 | 4.0.6.2.4 | Training run cycle 3 (final) | 5d | 2027-02-10 | 2027-02-16 | 321 | X. Alvarado2; Y. Whitby3 |
| 323 | 4.0.6.3 | Bias & fairness evaluation | 8d | 2027-02-17 | 2027-02-26 | 318 | F. Bennett; C. Garcia2 |
| 324 | 4.0.6.4 | Explainability & guardrail implementation | 8d | 2027-03-01 | 2027-03-10 | 323 | Y. Whitby3; Z. Okoro3 |
| 325 | 4.0.6.5 | Model documentation & model card | 6d | 2027-03-11 | 2027-03-18 | 324 | Z. Okoro3; A. Delacroix3 [90%] |
| 326 | 4.0.6.6 | Model peer review (first line) | 5d | 2027-03-19 | 2027-03-25 | 325 | B. Vartan3; A. Delacroix3 [90%] |

| ID | WBS | Task | Type | Duration | Start | Finish | Predecessors | Resources |
| --- | --- | --- | --- | --- | --- | --- | --- | --- |
| 327 | 4.0.7 | **Iterative Build (Sprints)** |  | 72d | 2027-01-13 | 2027-04-22 |  |  |
| 328 | 4.0.7.1 | **Sprint 1 — build & integrate** |  | 9d | 2027-01-13 | 2027-01-25 |  |  |
| 329 | 4.0.7.1.1 | Sprint 1 planning & backlog refinement | milestone | 1d | 2027-01-13 | 2027-01-13 |  | B. Vartan3; C. Halvorsen3 |
| 330 | 4.0.7.1.2 | Sprint 1 feature & model development |  | 5d | 2027-01-14 | 2027-01-20 | 329 | C. Halvorsen3; F. Bennett; C. Garcia2; D. Thompson2; E. Washington2 |
| 331 | 4.0.7.1.3 | Sprint 1 code review & merge |  | 2d | 2027-01-21 | 2027-01-22 | 330 | E. Washington2; F. Ferraro2 |
| 332 | 4.0.7.1.4 | Sprint 1 demo, review & retrospective | milestone | 1d | 2027-01-25 | 2027-01-25 | 331 | F. Ferraro2; G. Delacroix2 |
| 333 | 4.0.7.2 | **Sprint 2 — build & integrate** |  | 9d | 2027-01-26 | 2027-02-05 |  |  |
| 334 | 4.0.7.2.1 | Sprint 2 planning & backlog refinement | milestone | 1d | 2027-01-26 | 2027-01-26 | 328 | G. Delacroix2; H. Vartan2 |
| 335 | 4.0.7.2.2 | Sprint 2 feature & model development |  | 5d | 2027-01-27 | 2027-02-02 | 334 | H. Vartan2; I. Halvorsen2; J. Nakamura2; K. Okoro2; L. Whitby2 |
| 336 | 4.0.7.2.3 | Sprint 2 code review & merge |  | 2d | 2027-02-03 | 2027-02-04 | 335 | L. Whitby2; M. Beaumont2 |
| 337 | 4.0.7.2.4 | Sprint 2 demo, review & retrospective | milestone | 1d | 2027-02-05 | 2027-02-05 | 336 | M. Beaumont2; N. Kowalczyk3 |
| 338 | 4.0.7.3 | **Sprint 3 — build & integrate** |  | 9d | 2027-02-08 | 2027-02-18 |  |  |
| 339 | 4.0.7.3.1 | Sprint 3 planning & backlog refinement | milestone | 1d | 2027-02-08 | 2027-02-08 | 333 | N. Kowalczyk3; O. Delvecchio3 |
| 340 | 4.0.7.3.2 | Sprint 3 feature & model development |  | 5d | 2027-02-09 | 2027-02-15 | 339 | O. Delvecchio3; P. Solberg3; Q. Nakashima3; R. Winfield3; S. Achebe3 |
| 341 | 4.0.7.3.3 | Sprint 3 code review & merge |  | 2d | 2027-02-16 | 2027-02-17 | 340 | S. Achebe3; T. Larsen3 |
| 342 | 4.0.7.3.4 | Sprint 3 demo, review & retrospective | milestone | 1d | 2027-02-18 | 2027-02-18 | 341 | T. Larsen3; U. Sorensen3 |
| 343 | 4.0.7.4 | **Sprint 4 — build & integrate** |  | 9d | 2027-02-19 | 2027-03-03 |  |  |
| 344 | 4.0.7.4.1 | Sprint 4 planning & backlog refinement | milestone | 1d | 2027-02-19 | 2027-02-19 | 338 | U. Sorensen3; V. Kessler2 |
| 345 | 4.0.7.4.2 | Sprint 4 feature & model development |  | 5d | 2027-02-22 | 2027-02-26 | 344 | V. Kessler2; W. Rutherford2; X. Alvarado2; Y. Whitby3; Z. Okoro3 |
| 346 | 4.0.7.4.3 | Sprint 4 code review & merge |  | 2d | 2027-03-01 | 2027-03-02 | 345 | Z. Okoro3; A. Delacroix3 [90%] |
| 347 | 4.0.7.4.4 | Sprint 4 demo, review & retrospective | milestone | 1d | 2027-03-03 | 2027-03-03 | 346 | B. Vartan3; A. Delacroix3 [90%] |
| 348 | 4.0.7.5 | **Sprint 5 — build & integrate** |  | 9d | 2027-03-04 | 2027-03-16 |  |  |
| 349 | 4.0.7.5.1 | Sprint 5 planning & backlog refinement | milestone | 1d | 2027-03-04 | 2027-03-04 | 343 | B. Vartan3; C. Halvorsen3 |
| 350 | 4.0.7.5.2 | Sprint 5 feature & model development |  | 5d | 2027-03-05 | 2027-03-11 | 349 | C. Halvorsen3; F. Bennett; C. Garcia2; D. Thompson2; E. Washington2 |
| 351 | 4.0.7.5.3 | Sprint 5 code review & merge |  | 2d | 2027-03-12 | 2027-03-15 | 350 | E. Washington2; F. Ferraro2 |
| 352 | 4.0.7.5.4 | Sprint 5 demo, review & retrospective | milestone | 1d | 2027-03-16 | 2027-03-16 | 351 | F. Ferraro2; G. Delacroix2 |

| ID | WBS | Task | Type | Duration | Start | Finish | Predecessors | Resources |
| --- | --- | --- | --- | --- | --- | --- | --- | --- |
| 353 | 4.0.7.6 | **Sprint 6 — build & integrate** |  | 9d | 2027-03-17 | 2027-03-29 |  |  |
| 354 | 4.0.7.6.1 | Sprint 6 planning & backlog refinement | milestone | 1d | 2027-03-17 | 2027-03-17 | 348 | G. Delacroix2; H. Vartan2 |
| 355 | 4.0.7.6.2 | Sprint 6 feature & model development |  | 5d | 2027-03-18 | 2027-03-24 | 354 | H. Vartan2; I. Halvorsen2; J. Nakamura2; K. Okoro2; L. Whitby2 |
| 356 | 4.0.7.6.3 | Sprint 6 code review & merge |  | 2d | 2027-03-25 | 2027-03-26 | 355 | L. Whitby2; M. Beaumont2 |
| 357 | 4.0.7.6.4 | Sprint 6 demo, review & retrospective | milestone | 1d | 2027-03-29 | 2027-03-29 | 356 | M. Beaumont2; N. Kowalczyk3 |
| 358 | 4.0.7.7 | **Sprint 7 — build & integrate** |  | 9d | 2027-03-30 | 2027-04-09 |  |  |
| 359 | 4.0.7.7.1 | Sprint 7 planning & backlog refinement | milestone | 1d | 2027-03-30 | 2027-03-30 | 353 | N. Kowalczyk3; O. Delvecchio3 |
| 360 | 4.0.7.7.2 | Sprint 7 feature & model development |  | 5d | 2027-03-31 | 2027-04-06 | 359 | O. Delvecchio3; P. Solberg3; Q. Nakashima3; R. Winfield3; S. Achebe3 |
| 361 | 4.0.7.7.3 | Sprint 7 code review & merge |  | 2d | 2027-04-07 | 2027-04-08 | 360 | S. Achebe3; T. Larsen3 |
| 362 | 4.0.7.7.4 | Sprint 7 demo, review & retrospective | milestone | 1d | 2027-04-09 | 2027-04-09 | 361 | T. Larsen3; U. Sorensen3 |
| 363 | 4.0.7.8 | **Sprint 8 — build & integrate** |  | 9d | 2027-04-12 | 2027-04-22 |  |  |
| 364 | 4.0.7.8.1 | Sprint 8 planning & backlog refinement | milestone | 1d | 2027-04-12 | 2027-04-12 | 358 | U. Sorensen3; V. Kessler2 |
| 365 | 4.0.7.8.2 | Sprint 8 feature & model development |  | 5d | 2027-04-13 | 2027-04-19 | 364 | V. Kessler2; W. Rutherford2; X. Alvarado2; Y. Whitby3; Z. Okoro3 |
| 366 | 4.0.7.8.3 | Sprint 8 code review & merge |  | 2d | 2027-04-20 | 2027-04-21 | 365 | Z. Okoro3; A. Delacroix3 [90%] |
| 367 | 4.0.7.8.4 | Sprint 8 demo, review & retrospective | milestone | 1d | 2027-04-22 | 2027-04-22 | 366 | B. Vartan3; A. Delacroix3 [90%] |
| 368 | 4.0.8 | **Integration & Environment Build** |  | 42d | 2027-01-29 | 2027-03-29 |  |  |
| 369 | 4.0.8.1 | **Application & workflow integration** |  | 20d | 2027-01-29 | 2027-02-25 |  |  |
| 370 | 4.0.8.1.1 | API & service integration |  | 8d | 2027-01-29 | 2027-02-09 |  | B. Vartan3; C. Halvorsen3; F. Bennett; C. Garcia2; D. Thompson2 |
| 371 | 4.0.8.1.2 | Human-in-the-loop review workflow |  | 6d | 2027-02-10 | 2027-02-17 | 370 | D. Thompson2; E. Washington2 |
| 372 | 4.0.8.1.3 | Channel / UI integration |  | 6d | 2027-02-18 | 2027-02-25 | 371 | E. Washington2; F. Ferraro2 |
| 373 | 4.0.8.2 | MLOps deployment pipeline setup |  | 10d | 2027-02-26 | 2027-03-11 | 369 | M. Marchetti; N. Whitcomb |
| 374 | 4.0.8.3 | Environment build & configuration |  | 6d | 2027-03-12 | 2027-03-19 | 373 | B. Fairweather; C. Sondheim; D. Marchetti; E. Whitcomb; F. Talbot |
| 375 | 4.0.8.4 | Integration smoke test & stabilization |  | 6d | 2027-03-22 | 2027-03-29 | 374 | F. Ferraro2; G. Delacroix2 |
| 376 | 4.0.9 | **Testing & QA** |  | 93d | 2027-02-16 | 2027-06-24 |  |  |
| 377 | 4.0.9.1 | Test strategy & plan |  | 6d | 2027-02-16 | 2027-02-23 |  | V. Müller; J. Bennett |
| 378 | 4.0.9.2 | Test case authoring & data setup |  | 10d | 2027-02-24 | 2027-03-09 | 377 | J. Bennett; K. Garcia; L. Thompson; M. Washington (QA); N. Ferraro |
| 379 | 4.0.9.3 | Unit & component testing |  | 10d | 2027-03-10 | 2027-03-23 | 378 | N. Ferraro; O. Delacroix; P. Vartan; Q. Halvorsen; R. Nakamura |
| 380 | 4.0.9.4 | Integration testing |  | 12d | 2027-03-24 | 2027-04-08 | 379 | R. Nakamura; S. Okoro; T. Whitby; U. Beaumont; V. Kowalczyk |

| ID | WBS | Task | Duration | Start | Finish | Predecessors | Resources |
| --- | --- | --- | --- | --- | --- | --- | --- |
| 381 | 4.0.9.5 | **System & end-to-end testing** | 12d | 2027-04-09 | 2027-04-26 |  |  |
| 382 | 4.0.9.5.1 | Functional E2E scenarios | 6d | 2027-04-09 | 2027-04-16 | 380 | V. Kowalczyk; W. Delvecchio; X. Solberg; Y. Nakashima (QA); Z. Winfield (QA) [90%] |
| 383 | 4.0.9.5.2 | Negative & edge-case testing | 6d | 2027-04-19 | 2027-04-26 | 382 | V. Müller; Z. Winfield (QA) [90%] |
| 384 | 4.0.9.6 | Model performance & regression testing | 10d | 2027-04-27 | 2027-05-10 | 381 | V. Müller; J. Bennett; K. Garcia |
| 385 | 4.0.9.7 | Security & penetration testing | 8d | 2027-05-11 | 2027-05-20 | 384 | N. Winthrop; O. Castillo; P. Halstead; Q. Beaumont; M. Hassan [20%] |
| 386 | 4.0.9.8 | Performance & load testing | 8d | 2027-05-21 | 2027-06-01 | 385 | V. Müller; J. Bennett |
| 387 | 4.0.9.9 | Defect triage & resolution cycles | 12d | 2027-06-02 | 2027-06-17 | 386 | K. Garcia; L. Thompson; M. Washington (QA); N. Ferraro; O. Delacroix |
| 388 | 4.0.9.10 | Test summary & exit report | 5d | 2027-06-18 | 2027-06-24 | 387 | J. Bennett; K. Garcia |
| 389 | 4.0.10 | **Independent Model Validation** | 27d | 2027-03-04 | 2027-04-09 |  |  |
| 390 | 4.0.10.1 | IMV submission & documentation review | 6d | 2027-03-04 | 2027-03-11 |  | P. Okafor; W. Achebe |
| 391 | 4.0.10.2 | **Independent performance & fairness validation** | 10d | 2027-03-12 | 2027-03-25 |  |  |
| 392 | 4.0.10.2.1 | Independent replication testing | 5d | 2027-03-12 | 2027-03-18 | 390 | W. Achebe; X. Sorensen |
| 393 | 4.0.10.2.2 | Fairness & bias re-testing | 5d | 2027-03-19 | 2027-03-25 | 392 | X. Sorensen; Y. Larsen |
| 394 | 4.0.10.3 | Validation findings & remediation | 8d | 2027-03-26 | 2027-04-06 | 391 | P. Okafor; W. Achebe; X. Sorensen |
| 395 | 4.0.10.4 | IMV sign-off (production gate) | 3d | 2027-04-07 | 2027-04-09 | 394 | Y. Larsen; Z. Winfield (IMV) |
| 396 | 4.0.11 | **Compliance, Clinical & Controls Review** | 39d | 2027-03-22 | 2027-05-13 |  |  |
| 397 | 4.0.11.1 | Legal review (liability, disclaimers, contracts) | 6d | 2027-03-22 | 2027-03-29 |  | K. Okonkwo; M. Bernstein; S. Patel [90%]; D. Flores [80%]; R. Thorne [20%] |
| 398 | 4.0.11.2 | Compliance & regulatory review | 8d | 2027-03-30 | 2027-04-08 | 397 | L. Huang; T. Jackson; R. Kimani [90%]; B. Cho [85%]; C. Morrison [80%] |
| 399 | 4.0.11.3 | Clinical / medical-policy review | 7d | 2027-04-09 | 2027-04-19 | 398 | L. Delacroix [90%]; M. Beaumont [80%]; Dr. J. Whitby [80%]; Dr. I. Alvarado [50%]; Dr. N. Patel [25%] |
| 400 | 4.0.11.4 | SOX / financial-controls testing | 6d | 2027-04-20 | 2027-04-27 | 399 | M. Osei; N. Brennan; P. Whitcomb; O. Fairweather [90%]; K. Williams [25%] |
| 401 | 4.0.11.5 | Data privacy audit & DPIA | 6d | 2027-04-28 | 2027-05-05 | 400 | N. Achterberg; O. Whitlock |
| 402 | 4.0.11.6 | Cybersecurity controls assurance | 6d | 2027-05-06 | 2027-05-13 | 401 | Q. Beaumont; R. Fontaine |
| 403 | 4.0.12 | **User Acceptance Testing** | 49d | 2027-04-07 | 2027-06-14 |  |  |
| 404 | 4.0.12.1 | UAT planning & environment readiness | 6d | 2027-04-07 | 2027-04-14 |  | Y. Sorensen6; Z. Kessler5 [50%]; A. Rutherford5 [50%]; B. Alvarado5 [50%]; C. Whitby8 [50%] |
| 405 | 4.0.12.2 | UAT test scenario authoring | 8d | 2027-04-15 | 2027-04-26 | 404 | C. Whitby8 [50%]; D. Okoro8 [50%]; E. Beaumont6 [50%]; F. Kowalczyk7 [50%]; G. Delvecchio7 [50%] |

| ID | WBS | Task | Duration | Start | Finish | Predecessors | Resources |
| --- | --- | --- | --- | --- | --- | --- | --- |
| 406 | 4.0.12.3 | **UAT execution cycles** | 20d | 2027-04-27 | 2027-05-24 |  |  |
| 407 | 4.0.12.3.1 | UAT cycle 1 | 6d | 2027-04-27 | 2027-05-04 | 405 | Y. Sorensen6; H. Solberg7 [80%]; I. Nakashima7 [70%]; G. Delvecchio7 [50%]; Z. Kessler5 [50%] |
| 408 | 4.0.12.3.2 | UAT defect fixes & retest | 5d | 2027-05-05 | 2027-05-11 | 407 | Z. Kessler5 [50%]; A. Rutherford5 [50%]; B. Alvarado5 [50%]; C. Whitby8 [50%]; D. Okoro8 [50%] |
| 409 | 4.0.12.3.3 | UAT cycle 2 (regression) | 5d | 2027-05-12 | 2027-05-18 | 408 | H. Solberg7 [80%]; D. Okoro8 [50%]; E. Beaumont6 [50%]; F. Kowalczyk7 [50%]; G. Delvecchio7 [50%] |
| 410 | 4.0.12.3.4 | Final UAT confirmation | 4d | 2027-05-19 | 2027-05-24 | 409 | Y. Sorensen6; H. Solberg7 [80%]; I. Nakashima7 [70%]; Z. Kessler5 [50%]; A. Rutherford5 [50%] |
| 411 | 4.0.12.4 | Business process & runbook validation | 6d | 2027-05-25 | 2027-06-01 | 406 | F. Talbot; G. Restrepo; H. Vartan; I. Halvorsen [80%]; H. Nakamura [30%] |
| 412 | 4.0.12.5 | Operational readiness assessment | 6d | 2027-06-02 | 2027-06-09 | 411 | N. Alvarado4; O. Whitby7; P. Okoro7; Q. Beaumont5; M. Washington (CustOps) [20%] |
| 413 | 4.0.12.6 | UAT sign-off | 3d | 2027-06-10 | 2027-06-14 | 412 | A. Rutherford5 [50%]; B. Alvarado5 [50%] |
| 414 | 4.0.13 | **Change Management & Adoption** | 55d | 2027-04-23 | 2027-07-08 |  |  |
| 415 | 4.0.13.1 | Change impact assessment & stakeholder analysis | 7d | 2027-04-23 | 2027-05-03 |  | E. Winthrop [90%]; F. Achebe [80%] |
| 416 | 4.0.13.2 | **Training material development** | 10d | 2027-05-04 | 2027-05-17 |  |  |
| 417 | 4.0.13.2.1 | End-user training curriculum | 5d | 2027-05-04 | 2027-05-10 | 415 | F. Achebe [80%]; H. Kandel [70%] |
| 418 | 4.0.13.2.2 | Job aids & quick-reference | 5d | 2027-05-11 | 2027-05-17 | 417 | I. Redmond [80%]; H. Kandel [70%] |
| 419 | 4.0.13.3 | Training delivery & enablement | 12d | 2027-05-18 | 2027-06-02 | 416 | G. Okonkwo; B. Prescott; C. Whitfield; D. Solis; I. Redmond [80%] |
| 420 | 4.0.13.4 | Communications campaign | 8d | 2027-06-03 | 2027-06-14 | 419 | R. Castellanos [90%]; S. Halloway [80%]; T. Ainslie [70%]; B. Sullivan [30%] |
| 421 | 4.0.13.5 | Frontline readiness & super-user network | 8d | 2027-06-15 | 2027-06-24 | 420 | Q. Beaumont5; S. Delvecchio6; T. Solberg6; R. Kowalczyk6 [90%]; U. Nakashima6 [80%] |
| 422 | 4.0.13.6 | Adoption tracking & reinforcement | 10d | 2027-06-25 | 2027-07-08 | 421 | D. Solis; E. Winthrop [90%] |
| 423 | 4.0.14 | **Pilot Deployment** | 40d | 2027-05-11 | 2027-07-05 |  |  |
| 424 | 4.0.14.1 | Pilot readiness review & go/no-go | 4d | 2027-05-11 | 2027-05-14 |  | G. Delacroix2; H. Vartan2 |
| 425 | 4.0.14.2 | Controlled pilot rollout | 12d | 2027-05-17 | 2027-06-01 | 424 | H. Vartan2; I. Halvorsen2; J. Nakamura2; K. Okoro2; L. Whitby2 |
| 426 | 4.0.14.3 | Pilot monitoring & tuning | 10d | 2027-06-02 | 2027-06-15 | 425 | C. Garcia2; D. Thompson2; E. Washington2 |
| 427 | 4.0.14.4 | Pilot support & issue resolution | 10d | 2027-06-16 | 2027-06-29 | 426 | X. Larsen6; U. Nakashima6 [80%]; V. Winfield6 [80%]; W. Achebe6 [70%]; M. Washington (CustOps) [20%] |
| 428 | 4.0.14.5 | Pilot evaluation & production decision | 4d | 2027-06-30 | 2027-07-05 | 427 | L. Whitby2; M. Beaumont2 |
| 429 | 4.0.15 | **Production Deployment & Hypercare** | 48d | 2027-05-27 | 2027-08-02 |  |  |
| 430 | 4.0.15.1 | Production readiness review (3 boards) | 5d | 2027-05-27 | 2027-06-02 |  | M. Beaumont2; N. Kowalczyk3 |
| 431 | 4.0.15.2 | Production cutover & go-live | 6d | 2027-06-03 | 2027-06-10 | 430 | F. Bennett; C. Garcia2; D. Thompson2; E. Washington2; F. Ferraro2 |

| ID | WBS | Task | Duration | Start | Finish | Predecessors | Resources |
| --- | --- | --- | --- | --- | --- | --- | --- |
| 432 | 4.0.15.3 | **Hypercare & stabilization** | 15d | 2027-06-11 | 2027-07-01 |  |  |
| 433 | 4.0.15.3.1 | Hypercare monitoring | 8d | 2027-06-11 | 2027-06-22 | 431 | N. Kowalczyk3; O. Delvecchio3; P. Solberg3; Q. Nakashima3; R. Winfield3 |
| 434 | 4.0.15.3.2 | Incident response & fixes | 7d | 2027-06-23 | 2027-07-01 | 433 | R. Winfield3; S. Achebe3; T. Larsen3; U. Sorensen3; V. Kessler2 |
| 435 | 4.0.15.4 | Post-go-live service desk support | 12d | 2027-07-02 | 2027-07-19 | 432 | N. Alvarado4; O. Whitby7; P. Okoro7; Q. Beaumont5; M. Washington (CustOps) [20%] |
| 436 | 4.0.15.5 | Benefits baseline established | 4d | 2027-07-20 | 2027-07-23 | 435 | F. Bennett; C. Garcia2 |
| 437 | 4.0.15.6 | Transition to steady-state operations | 6d | 2027-07-26 | 2027-08-02 | 436 | A. Prescott; H. Nakamura [30%] |
| 438 | 5.0 | **BRD-02 · Member & Provider Experience AI** | 230d | 2027-10-01 | 2028-08-17 |  |  |
| 439 | 5.0.1 | **Requirements & JAD** | 61d | 2027-10-01 | 2027-12-24 |  |  |
| 440 | 5.0.1.1 | **Requirements elicitation workshops (JAD series)** | 17d | 2027-10-01 | 2027-10-25 |  |  |
| 441 | 5.0.1.1.1 | Current-state process mapping | 6d | 2027-10-01 | 2027-10-08 |  | X. Garcia; D. Nakamura3 |
| 442 | 5.0.1.1.2 | Use-case & user-story definition | 6d | 2027-10-11 | 2027-10-18 | 441 | D. Nakamura3; E. Okoro4; F. Whitby4; G. Beaumont3; H. Kowalczyk4 |
| 443 | 5.0.1.1.3 | Non-functional & compliance requirements | 5d | 2027-10-19 | 2027-10-25 | 442 | X. Garcia; D. Nakamura3 |
| 444 | 5.0.1.2 | **Data & source-system requirements** | 8d | 2027-10-26 | 2027-11-04 |  |  |
| 445 | 5.0.1.2.1 | Source-system inventory | 4d | 2027-10-26 | 2027-10-29 | 440 | N. Whitcomb; O. Talbot |
| 446 | 5.0.1.2.2 | Data availability & quality requirements | 4d | 2027-11-01 | 2027-11-04 | 445 | O. Talbot; P. Restrepo2 |
| 447 | 5.0.1.3 | Model & decision-logic requirements | 8d | 2027-11-05 | 2027-11-16 | 444 | H. Kowalczyk4; I. Delvecchio4 |
| 448 | 5.0.1.4 | Business rules & policy catalogue | 7d | 2027-11-17 | 2027-11-25 | 447 | X. Garcia; D. Nakamura3 |
| 449 | 5.0.1.5 | Clinical / actuarial SME requirements review | 6d | 2027-11-26 | 2027-12-03 | 448 | X. Delgado; Y. Nakashima (UX); J. Lee; Z. Fairbanks [90%]; A. Castillo [80%] |
| 450 | 5.0.1.6 | Requirements traceability matrix baseline | 5d | 2027-12-06 | 2027-12-10 | 449 | I. Delvecchio4; J. Solberg4 |
| 451 | 5.0.1.7 | Requirements review & BRD authoring | 7d | 2027-12-13 | 2027-12-21 | 450 | J. Solberg4; K. Nakashima4 |
| 452 | 5.0.1.8 | BRD sign-off (JAD close, AI Governance Board) | 3d | 2027-12-22 | 2027-12-24 | 451 | K. Nakashima4; L. Winfield4 |
| 453 | 5.0.2 | **Architecture & Design** | 57d | 2027-10-20 | 2028-01-06 |  |  |
| 454 | 5.0.2.1 | **Solution architecture & integration design** | 12d | 2027-10-20 | 2027-11-04 |  |  |
| 455 | 5.0.2.1.1 | Target-state architecture | 6d | 2027-10-20 | 2027-10-27 |  | H. Delgado; I. Suzuki |
| 456 | 5.0.2.1.2 | Integration & API design | 6d | 2027-10-28 | 2027-11-04 | 455 | I. Suzuki; J. Kowalczyk |
| 457 | 5.0.2.2 | Data architecture & pipeline design | 10d | 2027-11-05 | 2027-11-18 | 454 | P. Restrepo2; Q. Halvorsen2 |

| ID | WBS | Task | Duration | Start | Finish | Predecessors | Resources |
| --- | --- | --- | --- | --- | --- | --- | --- |
| 458 | 5.0.2.3 | **Model design & approach selection** | 10d | 2027-11-19 | 2027-12-02 |  |  |
| 459 | 5.0.2.3.1 | Model approach evaluation | 5d | 2027-11-19 | 2027-11-25 | 457 | L. Winfield4; M. Achebe4 |
| 460 | 5.0.2.3.2 | Model design specification | 5d | 2027-11-26 | 2027-12-02 | 459 | M. Achebe4; N. Larsen4 |
| 461 | 5.0.2.4 | Security threat model & controls design | 8d | 2027-12-03 | 2027-12-14 | 458 | R. Fontaine; S. Vasquez; T. Delvecchio; U. Kandel [90%]; V. Redmond [80%] |
| 462 | 5.0.2.5 | Privacy-by-design & PHI data-flow review | 6d | 2027-12-15 | 2027-12-22 | 461 | O. Whitlock; P. Sandoval [90%] |
| 463 | 5.0.2.6 | Infrastructure & environment design | 7d | 2027-12-23 | 2027-12-31 | 462 | A. Prescott; B. Fairweather |
| 464 | 5.0.2.7 | Design review & EARB approval | 4d | 2028-01-03 | 2028-01-06 | 463 | J. Kowalczyk; K. Andersen [80%] |
| 465 | 5.0.3 | **Experience & Interaction Design** | 64d | 2027-11-08 | 2028-02-03 |  |  |
| 466 | 5.0.3.1 | User research & journey mapping | 10d | 2027-11-08 | 2027-11-19 |  | J. Lee; U. Marchetti; V. Okwuosa; W. Pham; X. Delgado |
| 467 | 5.0.3.2 | Information architecture & wireframes | 12d | 2027-11-22 | 2027-12-07 | 466 | X. Delgado; Y. Nakashima (UX); J. Lee; Z. Fairbanks [90%]; A. Castillo [80%] |
| 468 | 5.0.3.3 | Design system & component library | 12d | 2027-12-08 | 2027-12-23 | 467 | J. Lee; U. Marchetti; V. Okwuosa; W. Pham; X. Delgado |
| 469 | 5.0.3.4 | Conversational / interaction design | 10d | 2027-12-24 | 2028-01-06 | 468 | X. Delgado; Y. Nakashima (UX); J. Lee; Z. Fairbanks [90%]; A. Castillo [80%] |
| 470 | 5.0.3.5 | Accessibility & WCAG compliance review | 8d | 2028-01-07 | 2028-01-18 | 469 | J. Lee; U. Marchetti; V. Okwuosa; W. Pham; X. Delgado |
| 471 | 5.0.3.6 | **Usability testing & design iteration** | 12d | 2028-01-19 | 2028-02-03 |  |  |
| 472 | 5.0.3.6.1 | Usability test sessions | 6d | 2028-01-19 | 2028-01-26 | 470 | X. Delgado; Y. Nakashima (UX); J. Lee; Z. Fairbanks [90%]; A. Castillo [80%] |
| 473 | 5.0.3.6.2 | Design refinement from findings | 6d | 2028-01-27 | 2028-02-03 | 472 | J. Lee; U. Marchetti; V. Okwuosa; W. Pham; X. Delgado |
| 474 | 5.0.4 | **Clinical / Business Policy Alignment** | 36d | 2027-11-25 | 2028-01-13 |  |  |
| 475 | 5.0.4.1 | Clinical policy & medical necessity criteria review | 10d | 2027-11-25 | 2027-12-08 |  | X. Delgado; Y. Nakashima (UX); J. Lee; Z. Fairbanks [90%]; A. Castillo [80%] |
| 476 | 5.0.4.2 | Decision-logic clinical validation | 10d | 2027-12-09 | 2027-12-22 | 475 | J. Lee; U. Marchetti; V. Okwuosa; W. Pham; X. Delgado |
| 477 | 5.0.4.3 | Provider & utilization-management impact review | 8d | 2027-12-23 | 2028-01-03 | 476 | X. Delgado; Y. Nakashima (UX); J. Lee; Z. Fairbanks [90%]; A. Castillo [80%] |
| 478 | 5.0.4.4 | Policy exception & appeals handling design | 8d | 2028-01-04 | 2028-01-13 | 477 | J. Lee; U. Marchetti; V. Okwuosa |
| 479 | 5.0.5 | **Data Engineering & Feature Prep** | 61d | 2027-12-14 | 2028-03-07 |  |  |
| 480 | 5.0.5.1 | **Data profiling & quality assessment** | 12d | 2027-12-14 | 2027-12-29 |  |  |
| 481 | 5.0.5.1.1 | Legacy source profiling | 6d | 2027-12-14 | 2027-12-21 |  | Q. Halvorsen2; R. Bianchi; S. Fitzgerald; T. Andersen; U. Kowalczyk2 |
| 482 | 5.0.5.1.2 | Data quality scorecard & remediation plan | 6d | 2027-12-22 | 2027-12-29 | 481 | U. Kowalczyk2; V. Delvecchio2 |

| ID | WBS | Task | Type | Duration | Start | Finish | Predecessors | Resources |
| --- | --- | --- | --- | --- | --- | --- | --- | --- |
| 483 | 5.0.5.2 | **Data ingestion & pipeline build** |  | 15d | 2027-12-30 | 2028-01-19 |  |  |
| 484 | 5.0.5.2.1 | Source connectors & ingestion |  | 7d | 2027-12-30 | 2028-01-07 | 480 | V. Delvecchio2; W. Solberg2; X. Nakashima2; Y. Winfield2; Z. Achebe2 |
| 485 | 5.0.5.2.2 | Transformation & cleansing rules |  | 8d | 2028-01-10 | 2028-01-19 | 484 | Z. Achebe2; A. Larsen2 [90%] |
| 486 | 5.0.5.3 | Data remediation execution |  | 12d | 2028-01-20 | 2028-02-04 | 483 | W. Kumar; J. Restrepo; K. Vartan; A. Larsen2 [90%]; B. Sorensen2 [90%] |
| 487 | 5.0.5.4 | Feature engineering & dataset assembly |  | 12d | 2028-02-07 | 2028-02-22 | 486 | X. Garcia; D. Nakamura3; E. Okoro4 |
| 488 | 5.0.5.5 | Data privacy & PHI controls validation |  | 6d | 2028-02-23 | 2028-03-01 | 487 | P. Sandoval [90%]; Q. Beckham [80%] |
| 489 | 5.0.5.6 | Training / test dataset governance sign-off |  | 4d | 2028-03-02 | 2028-03-07 | 488 | D. Ibrahim; S. Khurana |
| 490 | 5.0.6 | **Model Development & Training** |  | 64d | 2027-12-31 | 2028-03-29 |  |  |
| 491 | 5.0.6.1 | Baseline model build |  | 15d | 2027-12-31 | 2028-01-20 |  | N. Larsen4; O. Sorensen4; P. Kessler3 |
| 492 | 5.0.6.2 | **Model training & iteration cycles** |  | 22d | 2028-01-21 | 2028-02-21 |  |  |
| 493 | 5.0.6.2.1 | Training run cycle 1 |  | 6d | 2028-01-21 | 2028-01-28 | 491 | P. Kessler3; S. Whitby5; T. Okoro5; Q. Rutherford3 [90%]; R. Alvarado3 [80%] |
| 494 | 5.0.6.2.2 | Evaluation & error analysis |  | 5d | 2028-01-31 | 2028-02-04 | 493 | T. Okoro5; U. Delacroix4 [80%] |
| 495 | 5.0.6.2.3 | Training run cycle 2 (tuned) |  | 6d | 2028-02-07 | 2028-02-14 | 494 | V. Vartan4; X. Garcia; W. Halvorsen4 [90%]; U. Delacroix4 [80%]; Y. Nakamura4 [70%] |
| 496 | 5.0.6.2.4 | Training run cycle 3 (final) |  | 5d | 2028-02-15 | 2028-02-21 | 495 | X. Garcia; D. Nakamura3 |
| 497 | 5.0.6.3 | Bias & fairness evaluation |  | 8d | 2028-02-22 | 2028-03-02 | 492 | X. Garcia; D. Nakamura3 |
| 498 | 5.0.6.4 | Explainability & guardrail implementation |  | 8d | 2028-03-03 | 2028-03-14 | 497 | D. Nakamura3; E. Okoro4 |
| 499 | 5.0.6.5 | Model documentation & model card |  | 6d | 2028-03-15 | 2028-03-22 | 498 | E. Okoro4; F. Whitby4 |
| 500 | 5.0.6.6 | Model peer review (first line) |  | 5d | 2028-03-23 | 2028-03-29 | 499 | F. Whitby4; G. Beaumont3 |
| 501 | 5.0.7 | **Iterative Build (Sprints)** |  | 72d | 2028-01-19 | 2028-04-27 |  |  |
| 502 | 5.0.7.1 | **Sprint 1 — build & integrate** |  | 9d | 2028-01-19 | 2028-01-31 |  |  |
| 503 | 5.0.7.1.1 | Sprint 1 planning & backlog refinement | milestone | 1d | 2028-01-19 | 2028-01-19 |  | G. Beaumont3; H. Kowalczyk4 |
| 504 | 5.0.7.1.2 | Sprint 1 feature & model development |  | 5d | 2028-01-20 | 2028-01-26 | 503 | H. Kowalczyk4; I. Delvecchio4; J. Solberg4; K. Nakashima4; L. Winfield4 |
| 505 | 5.0.7.1.3 | Sprint 1 code review & merge |  | 2d | 2028-01-27 | 2028-01-28 | 504 | L. Winfield4; M. Achebe4 |
| 506 | 5.0.7.1.4 | Sprint 1 demo, review & retrospective | milestone | 1d | 2028-01-31 | 2028-01-31 | 505 | M. Achebe4; N. Larsen4 |

| ID | WBS | Task | Type | Duration | Start | Finish | Predecessors | Resources |
| --- | --- | --- | --- | --- | --- | --- | --- | --- |
| 507 | 5.0.7.2 | **Sprint 2 — build & integrate** |  | 9d | 2028-02-01 | 2028-02-11 |  |  |
| 508 | 5.0.7.2.1 | Sprint 2 planning & backlog refinement | milestone | 1d | 2028-02-01 | 2028-02-01 | 502 | N. Larsen4; O. Sorensen4 |
| 509 | 5.0.7.2.2 | Sprint 2 feature & model development |  | 5d | 2028-02-02 | 2028-02-08 | 508 | O. Sorensen4; P. Kessler3; S. Whitby5; Q. Rutherford3 [90%]; R. Alvarado3 [80%] |
| 510 | 5.0.7.2.3 | Sprint 2 code review & merge |  | 2d | 2028-02-09 | 2028-02-10 | 509 | S. Whitby5; T. Okoro5 |
| 511 | 5.0.7.2.4 | Sprint 2 demo, review & retrospective | milestone | 1d | 2028-02-11 | 2028-02-11 | 510 | T. Okoro5; U. Delacroix4 [80%] |
| 512 | 5.0.7.3 | **Sprint 3 — build & integrate** |  | 9d | 2028-02-14 | 2028-02-24 |  |  |
| 513 | 5.0.7.3.1 | Sprint 3 planning & backlog refinement | milestone | 1d | 2028-02-14 | 2028-02-14 | 507 | V. Vartan4; U. Delacroix4 [80%] |
| 514 | 5.0.7.3.2 | Sprint 3 feature & model development |  | 5d | 2028-02-15 | 2028-02-21 | 513 | V. Vartan4; X. Garcia; D. Nakamura3; W. Halvorsen4 [90%]; Y. Nakamura4 [70%] |
| 515 | 5.0.7.3.3 | Sprint 3 code review & merge |  | 2d | 2028-02-22 | 2028-02-23 | 514 | D. Nakamura3; E. Okoro4 |
| 516 | 5.0.7.3.4 | Sprint 3 demo, review & retrospective | milestone | 1d | 2028-02-24 | 2028-02-24 | 515 | E. Okoro4; F. Whitby4 |
| 517 | 5.0.7.4 | **Sprint 4 — build & integrate** |  | 9d | 2028-02-25 | 2028-03-08 |  |  |
| 518 | 5.0.7.4.1 | Sprint 4 planning & backlog refinement | milestone | 1d | 2028-02-25 | 2028-02-25 | 512 | F. Whitby4; G. Beaumont3 |
| 519 | 5.0.7.4.2 | Sprint 4 feature & model development |  | 5d | 2028-02-28 | 2028-03-03 | 518 | G. Beaumont3; H. Kowalczyk4; I. Delvecchio4; J. Solberg4; K. Nakashima4 |
| 520 | 5.0.7.4.3 | Sprint 4 code review & merge |  | 2d | 2028-03-06 | 2028-03-07 | 519 | K. Nakashima4; L. Winfield4 |
| 521 | 5.0.7.4.4 | Sprint 4 demo, review & retrospective | milestone | 1d | 2028-03-08 | 2028-03-08 | 520 | L. Winfield4; M. Achebe4 |
| 522 | 5.0.7.5 | **Sprint 5 — build & integrate** |  | 9d | 2028-03-09 | 2028-03-21 |  |  |
| 523 | 5.0.7.5.1 | Sprint 5 planning & backlog refinement | milestone | 1d | 2028-03-09 | 2028-03-09 | 517 | M. Achebe4; N. Larsen4 |
| 524 | 5.0.7.5.2 | Sprint 5 feature & model development |  | 5d | 2028-03-10 | 2028-03-16 | 523 | N. Larsen4; O. Sorensen4; P. Kessler3; Q. Rutherford3 [90%]; R. Alvarado3 [80%] |
| 525 | 5.0.7.5.3 | Sprint 5 code review & merge |  | 2d | 2028-03-17 | 2028-03-20 | 524 | S. Whitby5; R. Alvarado3 [80%] |
| 526 | 5.0.7.5.4 | Sprint 5 demo, review & retrospective | milestone | 1d | 2028-03-21 | 2028-03-21 | 525 | S. Whitby5; T. Okoro5 |
| 527 | 5.0.7.6 | **Sprint 6 — build & integrate** |  | 9d | 2028-03-22 | 2028-04-03 |  |  |
| 528 | 5.0.7.6.1 | Sprint 6 planning & backlog refinement | milestone | 1d | 2028-03-22 | 2028-03-22 | 522 | T. Okoro5; U. Delacroix4 [80%] |
| 529 | 5.0.7.6.2 | Sprint 6 feature & model development |  | 5d | 2028-03-23 | 2028-03-29 | 528 | V. Vartan4; X. Garcia; W. Halvorsen4 [90%]; U. Delacroix4 [80%]; Y. Nakamura4 [70%] |
| 530 | 5.0.7.6.3 | Sprint 6 code review & merge |  | 2d | 2028-03-30 | 2028-03-31 | 529 | X. Garcia; D. Nakamura3 |
| 531 | 5.0.7.6.4 | Sprint 6 demo, review & retrospective | milestone | 1d | 2028-04-03 | 2028-04-03 | 530 | D. Nakamura3; E. Okoro4 |

| ID | WBS | Task | Type | Duration | Start | Finish | Predecessors | Resources |
| --- | --- | --- | --- | --- | --- | --- | --- | --- |
| 532 | 5.0.7.7 | **Sprint 7 — build & integrate** |  | 9d | 2028-04-04 | 2028-04-14 |  |  |
| 533 | 5.0.7.7.1 | Sprint 7 planning & backlog refinement | milestone | 1d | 2028-04-04 | 2028-04-04 | 527 | E. Okoro4; F. Whitby4 |
| 534 | 5.0.7.7.2 | Sprint 7 feature & model development |  | 5d | 2028-04-05 | 2028-04-11 | 533 | F. Whitby4; G. Beaumont3; H. Kowalczyk4; I. Delvecchio4; J. Solberg4 |
| 535 | 5.0.7.7.3 | Sprint 7 code review & merge |  | 2d | 2028-04-12 | 2028-04-13 | 534 | J. Solberg4; K. Nakashima4 |
| 536 | 5.0.7.7.4 | Sprint 7 demo, review & retrospective | milestone | 1d | 2028-04-14 | 2028-04-14 | 535 | K. Nakashima4; L. Winfield4 |
| 537 | 5.0.7.8 | **Sprint 8 — build & integrate** |  | 9d | 2028-04-17 | 2028-04-27 |  |  |
| 538 | 5.0.7.8.1 | Sprint 8 planning & backlog refinement | milestone | 1d | 2028-04-17 | 2028-04-17 | 532 | L. Winfield4; M. Achebe4 |
| 539 | 5.0.7.8.2 | Sprint 8 feature & model development |  | 5d | 2028-04-18 | 2028-04-24 | 538 | M. Achebe4; N. Larsen4; O. Sorensen4; P. Kessler3; Q. Rutherford3 [90%] |
| 540 | 5.0.7.8.3 | Sprint 8 code review & merge |  | 2d | 2028-04-25 | 2028-04-26 | 539 | Q. Rutherford3 [90%]; R. Alvarado3 [80%] |
| 541 | 5.0.7.8.4 | Sprint 8 demo, review & retrospective | milestone | 1d | 2028-04-27 | 2028-04-27 | 540 | S. Whitby5; R. Alvarado3 [80%] |
| 542 | 5.0.8 | **Integration & Environment Build** |  | 42d | 2028-02-07 | 2028-04-04 |  |  |
| 543 | 5.0.8.1 | **Application & workflow integration** |  | 20d | 2028-02-07 | 2028-03-03 |  |  |
| 544 | 5.0.8.1.1 | API & service integration |  | 8d | 2028-02-07 | 2028-02-16 |  | S. Whitby5; T. Okoro5; V. Vartan4; W. Halvorsen4 [90%]; U. Delacroix4 [80%] |
| 545 | 5.0.8.1.2 | Human-in-the-loop review workflow |  | 6d | 2028-02-17 | 2028-02-24 | 544 | W. Halvorsen4 [90%]; Y. Nakamura4 [70%] |
| 546 | 5.0.8.1.3 | Channel / UI integration |  | 6d | 2028-02-25 | 2028-03-03 | 545 | J. Lee; U. Marchetti |
| 547 | 5.0.8.2 | MLOps deployment pipeline setup |  | 10d | 2028-03-06 | 2028-03-17 | 543 | K. Vartan; L. Sondheim |
| 548 | 5.0.8.3 | Environment build & configuration |  | 6d | 2028-03-20 | 2028-03-27 | 547 | B. Fairweather; C. Sondheim; D. Marchetti; E. Whitcomb; F. Talbot |
| 549 | 5.0.8.4 | Integration smoke test & stabilization |  | 6d | 2028-03-28 | 2028-04-04 | 548 | X. Garcia; Y. Nakamura4 [70%] |
| 550 | 5.0.9 | **Testing & QA** |  | 93d | 2028-02-24 | 2028-07-03 |  |  |
| 551 | 5.0.9.1 | Test strategy & plan |  | 6d | 2028-02-24 | 2028-03-02 |  | K. Garcia; L. Thompson |
| 552 | 5.0.9.2 | Test case authoring & data setup |  | 10d | 2028-03-03 | 2028-03-16 | 551 | L. Thompson; M. Washington (QA); N. Ferraro; O. Delacroix; P. Vartan |
| 553 | 5.0.9.3 | Unit & component testing |  | 10d | 2028-03-17 | 2028-03-30 | 552 | P. Vartan; Q. Halvorsen; R. Nakamura; S. Okoro; T. Whitby |
| 554 | 5.0.9.4 | Integration testing |  | 12d | 2028-03-31 | 2028-04-17 | 553 | T. Whitby; U. Beaumont; V. Kowalczyk; W. Delvecchio; X. Solberg |
| 555 | 5.0.9.5 | **System & end-to-end testing** |  | 12d | 2028-04-18 | 2028-05-03 |  |  |
| 556 | 5.0.9.5.1 | Functional E2E scenarios |  | 6d | 2028-04-18 | 2028-04-25 | 554 | X. Solberg; Y. Nakashima (QA); V. Müller; J. Bennett; Z. Winfield (QA) [90%] |
| 557 | 5.0.9.5.2 | Negative & edge-case testing |  | 6d | 2028-04-26 | 2028-05-03 | 556 | J. Bennett; K. Garcia |
| 558 | 5.0.9.6 | Model performance & regression testing |  | 10d | 2028-05-04 | 2028-05-17 | 555 | V. Müller; J. Bennett; K. Garcia |
| 559 | 5.0.9.7 | Security & penetration testing |  | 8d | 2028-05-18 | 2028-05-29 | 558 | N. Winthrop; O. Castillo; P. Halstead; V. Redmond [80%]; M. Hassan [20%] |
| 560 | 5.0.9.8 | Performance & load testing |  | 8d | 2028-05-30 | 2028-06-08 | 559 | K. Garcia; L. Thompson |
| 561 | 5.0.9.9 | Defect triage & resolution cycles |  | 12d | 2028-06-09 | 2028-06-26 | 560 | K. Garcia; L. Thompson; M. Washington (QA); N. Ferraro; O. Delacroix |
| 562 | 5.0.9.10 | Test summary & exit report |  | 5d | 2028-06-27 | 2028-07-03 | 561 | L. Thompson; M. Washington (QA) |

| ID | WBS | Task | Duration | Start | Finish | Predecessors | Resources |
| --- | --- | --- | --- | --- | --- | --- | --- |
| 563 | 5.0.10 | **Independent Model Validation** | 27d | 2028-03-14 | 2028-04-19 |  |  |
| 564 | 5.0.10.1 | IMV submission & documentation review | 6d | 2028-03-14 | 2028-03-21 |  | Z. Winfield (IMV); A. Kessler [90%] |
| 565 | 5.0.10.2 | **Independent performance & fairness validation** | 10d | 2028-03-22 | 2028-04-04 |  |  |
| 566 | 5.0.10.2.1 | Independent replication testing | 5d | 2028-03-22 | 2028-03-28 | 564 | P. Okafor; A. Kessler [90%] |
| 567 | 5.0.10.2.2 | Fairness & bias re-testing | 5d | 2028-03-29 | 2028-04-04 | 566 | P. Okafor; W. Achebe |
| 568 | 5.0.10.3 | Validation findings & remediation | 8d | 2028-04-05 | 2028-04-14 | 565 | P. Okafor; W. Achebe; X. Sorensen |
| 569 | 5.0.10.4 | IMV sign-off (production gate) | 3d | 2028-04-17 | 2028-04-19 | 568 | W. Achebe; X. Sorensen |
| 570 | 5.0.11 | **Compliance, Clinical & Controls Review** | 39d | 2028-03-31 | 2028-05-24 |  |  |
| 571 | 5.0.11.1 | Legal review (liability, disclaimers, contracts) | 6d | 2028-03-31 | 2028-04-07 |  | N. Harris; K. Okonkwo; M. Bernstein; S. Patel [90%]; R. Thorne [20%] |
| 572 | 5.0.11.2 | Compliance & regulatory review | 8d | 2028-04-10 | 2028-04-19 | 571 | T. Jackson; L. Huang; R. Kimani [90%]; U. Kowalski [80%]; J. Martinez [30%] |
| 573 | 5.0.11.3 | Clinical / medical-policy review | 7d | 2028-04-20 | 2028-04-28 | 572 | U. Marchetti; V. Okwuosa; W. Pham; X. Delgado; Y. Nakashima (UX) |
| 574 | 5.0.11.4 | SOX / financial-controls testing | 6d | 2028-05-01 | 2028-05-08 | 573 | P. Whitcomb; M. Osei; N. Brennan; Q. Marchetti [80%]; K. Williams [25%] |
| 575 | 5.0.11.5 | Data privacy audit & DPIA | 6d | 2028-05-09 | 2028-05-16 | 574 | Q. Beckham [80%]; E. Sato [40%] |
| 576 | 5.0.11.6 | Cybersecurity controls assurance | 6d | 2028-05-17 | 2028-05-24 | 575 | P. Halstead; Q. Beaumont |
| 577 | 5.0.12 | **User Acceptance Testing** | 49d | 2028-04-19 | 2028-06-26 |  |  |
| 578 | 5.0.12.1 | UAT planning & environment readiness | 6d | 2028-04-19 | 2028-04-26 |  | B. Alvarado5 [50%]; C. Whitby8 [50%]; D. Okoro8 [50%]; E. Beaumont6 [50%]; F. Kowalczyk7 [50%] |
| 579 | 5.0.12.2 | UAT test scenario authoring | 8d | 2028-04-27 | 2028-05-08 | 578 | Y. Sorensen6; H. Solberg7 [80%]; I. Nakashima7 [70%]; F. Kowalczyk7 [50%]; G. Delvecchio7 [50%] |
| 580 | 5.0.12.3 | **UAT execution cycles** | 20d | 2028-05-09 | 2028-06-05 |  |  |
| 581 | 5.0.12.3.1 | UAT cycle 1 | 6d | 2028-05-09 | 2028-05-16 | 579 | Y. Sorensen6; Z. Kessler5 [50%]; A. Rutherford5 [50%]; B. Alvarado5 [50%]; C. Whitby8 [50%] |
| 582 | 5.0.12.3.2 | UAT defect fixes & retest | 5d | 2028-05-17 | 2028-05-23 | 581 | C. Whitby8 [50%]; D. Okoro8 [50%]; E. Beaumont6 [50%]; F. Kowalczyk7 [50%]; G. Delvecchio7 [50%] |
| 583 | 5.0.12.3.3 | UAT cycle 2 (regression) | 5d | 2028-05-24 | 2028-05-30 | 582 | Y. Sorensen6; H. Solberg7 [80%]; I. Nakashima7 [70%]; G. Delvecchio7 [50%]; Z. Kessler5 [50%] |
| 584 | 5.0.12.3.4 | Final UAT confirmation | 4d | 2028-05-31 | 2028-06-05 | 583 | Z. Kessler5 [50%]; A. Rutherford5 [50%]; B. Alvarado5 [50%]; C. Whitby8 [50%]; D. Okoro8 [50%] |
| 585 | 5.0.12.4 | Business process & runbook validation | 6d | 2028-06-06 | 2028-06-13 | 580 | F. Talbot; G. Restrepo; H. Vartan; I. Halvorsen [80%]; H. Nakamura [30%] |
| 586 | 5.0.12.5 | Operational readiness assessment | 6d | 2028-06-14 | 2028-06-21 | 585 | Q. Beaumont5; S. Delvecchio6; T. Solberg6; R. Kowalczyk6 [90%]; U. Nakashima6 [80%] |
| 587 | 5.0.12.6 | UAT sign-off | 3d | 2028-06-22 | 2028-06-26 | 586 | D. Okoro8 [50%]; E. Beaumont6 [50%] |

| ID | WBS | Task | Duration | Start | Finish | Predecessors | Resources |
| --- | --- | --- | --- | --- | --- | --- | --- |
| 588 | 5.0.13 | **Change Management & Adoption** | 55d | 2028-05-08 | 2028-07-21 |  |  |
| 589 | 5.0.13.1 | Change impact assessment & stakeholder analysis | 7d | 2028-05-08 | 2028-05-16 |  | E. Winthrop [90%]; F. Achebe [80%] |
| 590 | 5.0.13.2 | **Training material development** | 10d | 2028-05-17 | 2028-05-30 |  |  |
| 591 | 5.0.13.2.1 | End-user training curriculum | 5d | 2028-05-17 | 2028-05-23 | 589 | F. Achebe [80%]; H. Kandel [70%] |
| 592 | 5.0.13.2.2 | Job aids & quick-reference | 5d | 2028-05-24 | 2028-05-30 | 591 | I. Redmond [80%]; H. Kandel [70%] |
| 593 | 5.0.13.3 | Training delivery & enablement | 12d | 2028-05-31 | 2028-06-15 | 590 | G. Okonkwo; B. Prescott; C. Whitfield; D. Solis; I. Redmond [80%] |
| 594 | 5.0.13.4 | Communications campaign | 8d | 2028-06-16 | 2028-06-27 | 593 | R. Castellanos [90%]; S. Halloway [80%]; T. Ainslie [70%]; B. Sullivan [30%] |
| 595 | 5.0.13.5 | Frontline readiness & super-user network | 8d | 2028-06-28 | 2028-07-07 | 594 | X. Larsen6; U. Nakashima6 [80%]; V. Winfield6 [80%]; W. Achebe6 [70%]; M. Washington (CustOps) [20%] |
| 596 | 5.0.13.6 | Adoption tracking & reinforcement | 10d | 2028-07-10 | 2028-07-21 | 595 | D. Solis; E. Winthrop [90%] |
| 597 | 5.0.14 | **Pilot Deployment** | 40d | 2028-05-25 | 2028-07-19 |  |  |
| 598 | 5.0.14.1 | Pilot readiness review & go/no-go | 4d | 2028-05-25 | 2028-05-30 |  | X. Garcia; D. Nakamura3 |
| 599 | 5.0.14.2 | Controlled pilot rollout | 12d | 2028-05-31 | 2028-06-15 | 598 | D. Nakamura3; E. Okoro4; F. Whitby4; G. Beaumont3; H. Kowalczyk4 |
| 600 | 5.0.14.3 | Pilot monitoring & tuning | 10d | 2028-06-16 | 2028-06-29 | 599 | D. Nakamura3; E. Okoro4; F. Whitby4 |
| 601 | 5.0.14.4 | Pilot support & issue resolution | 10d | 2028-06-30 | 2028-07-13 | 600 | N. Alvarado4; O. Whitby7; P. Okoro7; Q. Beaumont5; M. Washington (CustOps) [20%] |
| 602 | 5.0.14.5 | Pilot evaluation & production decision | 4d | 2028-07-14 | 2028-07-19 | 601 | H. Kowalczyk4; I. Delvecchio4 |
| 603 | 5.0.15 | **Production Deployment & Hypercare** | 48d | 2028-06-13 | 2028-08-17 |  |  |
| 604 | 5.0.15.1 | Production readiness review (3 boards) | 5d | 2028-06-13 | 2028-06-19 |  | I. Delvecchio4; J. Solberg4 |
| 605 | 5.0.15.2 | Production cutover & go-live | 6d | 2028-06-20 | 2028-06-27 | 604 | X. Garcia; D. Nakamura3; E. Okoro4; F. Whitby4; G. Beaumont3 |
| 606 | 5.0.15.3 | **Hypercare & stabilization** | 15d | 2028-06-28 | 2028-07-18 |  |  |
| 607 | 5.0.15.3.1 | Hypercare monitoring | 8d | 2028-06-28 | 2028-07-07 | 605 | J. Solberg4; K. Nakashima4; L. Winfield4; M. Achebe4; N. Larsen4 |
| 608 | 5.0.15.3.2 | Incident response & fixes | 7d | 2028-07-10 | 2028-07-18 | 607 | N. Larsen4; O. Sorensen4; P. Kessler3; Q. Rutherford3 [90%]; R. Alvarado3 [80%] |
| 609 | 5.0.15.4 | Post-go-live service desk support | 12d | 2028-07-19 | 2028-08-03 | 606 | Q. Beaumont5; S. Delvecchio6; T. Solberg6; R. Kowalczyk6 [90%]; U. Nakashima6 [80%] |
| 610 | 5.0.15.5 | Benefits baseline established | 4d | 2028-08-04 | 2028-08-09 | 609 | X. Garcia; D. Nakamura3 |
| 611 | 5.0.15.6 | Transition to steady-state operations | 6d | 2028-08-10 | 2028-08-17 | 610 | U. Nakashima6 [80%]; V. Winfield6 [80%] |

| ID | WBS | Task | Duration | Start | Finish | Predecessors | Resources |
| --- | --- | --- | --- | --- | --- | --- | --- |
| 612 | 6.0 | **BRD-03 · Underwriting & Risk AI** | 258d | 2027-11-01 | 2028-10-25 |  |  |
| 613 | 6.0.1 | **Requirements & JAD** | 61d | 2027-11-01 | 2028-01-24 |  |  |
| 614 | 6.0.1.1 | **Requirements elicitation workshops (JAD series)** | 17d | 2027-11-01 | 2027-11-23 |  |  |
| 615 | 6.0.1.1.1 | Current-state process mapping | 6d | 2027-11-01 | 2027-11-08 |  | Z. Thompson; A. Okoro6 |
| 616 | 6.0.1.1.2 | Use-case & user-story definition | 6d | 2027-11-09 | 2027-11-16 | 615 | A. Okoro6; B. Whitby6; C. Beaumont4; D. Kowalczyk5; E. Delvecchio5 |
| 617 | 6.0.1.1.3 | Non-functional & compliance requirements | 5d | 2027-11-17 | 2027-11-23 | 616 | Z. Thompson; A. Okoro6 |
| 618 | 6.0.1.2 | **Data & source-system requirements** | 8d | 2027-11-24 | 2027-12-03 |  |  |
| 619 | 6.0.1.2.1 | Source-system inventory | 4d | 2027-11-24 | 2027-11-29 | 614 | L. Sondheim; M. Marchetti |
| 620 | 6.0.1.2.2 | Data availability & quality requirements | 4d | 2027-11-30 | 2027-12-03 | 619 | M. Marchetti; N. Whitcomb |
| 621 | 6.0.1.3 | Model & decision-logic requirements | 8d | 2027-12-06 | 2027-12-15 | 618 | E. Delvecchio5; F. Solberg5 |
| 622 | 6.0.1.4 | Business rules & policy catalogue | 7d | 2027-12-16 | 2027-12-24 | 621 | Z. Thompson; A. Okoro6 |
| 623 | 6.0.1.5 | Clinical / actuarial SME requirements review | 6d | 2027-12-27 | 2028-01-03 | 622 | K. Okoro; L. Delacroix [90%]; Dr. J. Whitby [80%]; M. Beaumont [80%]; Dr. N. Patel [25%] |
| 624 | 6.0.1.6 | Requirements traceability matrix baseline | 5d | 2028-01-04 | 2028-01-10 | 623 | F. Solberg5; G. Nakashima5 |
| 625 | 6.0.1.7 | Requirements review & BRD authoring | 7d | 2028-01-11 | 2028-01-19 | 624 | G. Nakashima5; H. Winfield5 |
| 626 | 6.0.1.8 | BRD sign-off (JAD close, AI Governance Board) | 3d | 2028-01-20 | 2028-01-24 | 625 | H. Winfield5; I. Achebe5 |
| 627 | 6.0.2 | **Architecture & Design** | 57d | 2027-11-22 | 2028-02-08 |  |  |
| 628 | 6.0.2.1 | **Solution architecture & integration design** | 12d | 2027-11-22 | 2027-12-07 |  |  |
| 629 | 6.0.2.1.1 | Target-state architecture | 6d | 2027-11-22 | 2027-11-29 |  | L. Fitzgerald; K. Andersen [80%] |
| 630 | 6.0.2.1.2 | Integration & API design | 6d | 2027-11-30 | 2027-12-07 | 629 | L. Fitzgerald; D. Chen [25%] |
| 631 | 6.0.2.2 | Data architecture & pipeline design | 10d | 2027-12-08 | 2027-12-21 | 628 | N. Whitcomb; O. Talbot |
| 632 | 6.0.2.3 | **Model design & approach selection** | 10d | 2027-12-22 | 2028-01-04 |  |  |
| 633 | 6.0.2.3.1 | Model approach evaluation | 5d | 2027-12-22 | 2027-12-28 | 631 | I. Achebe5; J. Larsen5 |
| 634 | 6.0.2.3.2 | Model design specification | 5d | 2027-12-29 | 2028-01-04 | 633 | J. Larsen5; K. Sorensen5 |
| 635 | 6.0.2.4 | Security threat model & controls design | 8d | 2028-01-05 | 2028-01-14 | 632 | Q. Beaumont; R. Fontaine; S. Vasquez; T. Delvecchio; U. Kandel [90%] |
| 636 | 6.0.2.5 | Privacy-by-design & PHI data-flow review | 6d | 2028-01-17 | 2028-01-24 | 635 | N. Achterberg; E. Sato [40%] |
| 637 | 6.0.2.6 | Infrastructure & environment design | 7d | 2028-01-25 | 2028-02-02 | 636 | A. Prescott; H. Nakamura [30%] |
| 638 | 6.0.2.7 | Design review & EARB approval | 4d | 2028-02-03 | 2028-02-08 | 637 | F. Okonkwo; D. Chen [25%] |

| ID | WBS | Task | Duration | Start | Finish | Predecessors | Resources |
| --- | --- | --- | --- | --- | --- | --- | --- |
| 639 | 6.0.3 | **Experience & Interaction Design** | 64d | 2027-12-13 | 2028-03-09 |  |  |
| 640 | 6.0.3.1 | User research & journey mapping | 10d | 2027-12-13 | 2027-12-24 |  | Y. Nakashima (UX); J. Lee; U. Marchetti; Z. Fairbanks [90%]; A. Castillo [80%] |
| 641 | 6.0.3.2 | Information architecture & wireframes | 12d | 2027-12-27 | 2028-01-11 | 640 | U. Marchetti; V. Okwuosa; W. Pham; X. Delgado; Y. Nakashima (UX) |
| 642 | 6.0.3.3 | Design system & component library | 12d | 2028-01-12 | 2028-01-27 | 641 | Y. Nakashima (UX); J. Lee; U. Marchetti; Z. Fairbanks [90%]; A. Castillo [80%] |
| 643 | 6.0.3.4 | Conversational / interaction design | 10d | 2028-01-28 | 2028-02-10 | 642 | U. Marchetti; V. Okwuosa; W. Pham; X. Delgado; Y. Nakashima (UX) |
| 644 | 6.0.3.5 | Accessibility & WCAG compliance review | 8d | 2028-02-11 | 2028-02-22 | 643 | Y. Nakashima (UX); J. Lee; U. Marchetti; Z. Fairbanks [90%]; A. Castillo [80%] |
| 645 | 6.0.3.6 | **Usability testing & design iteration** | 12d | 2028-02-23 | 2028-03-09 |  |  |
| 646 | 6.0.3.6.1 | Usability test sessions | 6d | 2028-02-23 | 2028-03-01 | 644 | U. Marchetti; V. Okwuosa; W. Pham; X. Delgado; Y. Nakashima (UX) |
| 647 | 6.0.3.6.2 | Design refinement from findings | 6d | 2028-03-02 | 2028-03-09 | 646 | Y. Nakashima (UX); J. Lee; U. Marchetti; Z. Fairbanks [90%]; A. Castillo [80%] |
| 648 | 6.0.4 | **Clinical / Business Policy Alignment** | 36d | 2028-01-03 | 2028-02-21 |  |  |
| 649 | 6.0.4.1 | Clinical policy & medical necessity criteria review | 10d | 2028-01-03 | 2028-01-14 |  | K. Okoro; L. Delacroix [90%]; Dr. J. Whitby [80%]; Dr. I. Alvarado [50%]; Dr. N. Patel [25%] |
| 650 | 6.0.4.2 | Decision-logic clinical validation | 10d | 2028-01-17 | 2028-01-28 | 649 | L. Delacroix [90%]; M. Beaumont [80%]; Dr. J. Whitby [80%]; Dr. I. Alvarado [50%]; Dr. N. Patel [25%] |
| 651 | 6.0.4.3 | Provider & utilization-management impact review | 8d | 2028-01-31 | 2028-02-09 | 650 | K. Okoro; L. Delacroix [90%]; Dr. J. Whitby [80%]; M. Beaumont [80%]; Dr. N. Patel [25%] |
| 652 | 6.0.4.4 | Policy exception & appeals handling design | 8d | 2028-02-10 | 2028-02-21 | 651 | K. Okoro; L. Delacroix [90%]; Dr. J. Whitby [80%] |
| 653 | 6.0.5 | **Data Engineering & Feature Prep** | 61d | 2028-01-24 | 2028-04-17 |  |  |
| 654 | 6.0.5.1 | **Data profiling & quality assessment** | 12d | 2028-01-24 | 2028-02-08 |  |  |
| 655 | 6.0.5.1.1 | Legacy source profiling | 6d | 2028-01-24 | 2028-01-31 |  | O. Talbot; P. Restrepo2; Q. Halvorsen2; R. Bianchi; S. Fitzgerald |
| 656 | 6.0.5.1.2 | Data quality scorecard & remediation plan | 6d | 2028-02-01 | 2028-02-08 | 655 | S. Fitzgerald; T. Andersen |
| 657 | 6.0.5.2 | **Data ingestion & pipeline build** | 15d | 2028-02-09 | 2028-02-29 |  |  |
| 658 | 6.0.5.2.1 | Source connectors & ingestion | 7d | 2028-02-09 | 2028-02-17 | 654 | T. Andersen; U. Kowalczyk2; V. Delvecchio2; W. Solberg2; X. Nakashima2 |
| 659 | 6.0.5.2.2 | Transformation & cleansing rules | 8d | 2028-02-18 | 2028-02-29 | 658 | X. Nakashima2; Y. Winfield2 |
| 660 | 6.0.5.3 | Data remediation execution | 12d | 2028-03-01 | 2028-03-16 | 657 | Y. Winfield2; Z. Achebe2; W. Kumar; A. Larsen2 [90%]; B. Sorensen2 [90%] |
| 661 | 6.0.5.4 | Feature engineering & dataset assembly | 12d | 2028-03-17 | 2028-04-03 | 660 | Z. Thompson; A. Okoro6; B. Whitby6 |
| 662 | 6.0.5.5 | Data privacy & PHI controls validation | 6d | 2028-04-04 | 2028-04-11 | 661 | N. Achterberg; O. Whitlock |
| 663 | 6.0.5.6 | Training / test dataset governance sign-off | 4d | 2028-04-12 | 2028-04-17 | 662 | S. Khurana; A. Reyes |

| ID | WBS | Task | Type | Duration | Start | Finish | Predecessors | Resources |
| --- | --- | --- | --- | --- | --- | --- | --- | --- |
| 664 | 6.0.6 | **Model Development & Training** |  | 64d | 2028-02-14 | 2028-05-11 |  |  |
| 665 | 6.0.6.1 | Baseline model build |  | 15d | 2028-02-14 | 2028-03-03 |  | K. Sorensen5; L. Kessler4; M. Rutherford4 |
| 666 | 6.0.6.2 | **Model training & iteration cycles** |  | 22d | 2028-03-06 | 2028-04-04 |  |  |
| 667 | 6.0.6.2.1 | Training run cycle 1 |  | 6d | 2028-03-06 | 2028-03-13 | 665 | M. Rutherford4; Z. Thompson; A. Okoro6; B. Whitby6; C. Beaumont4 |
| 668 | 6.0.6.2.2 | Evaluation & error analysis |  | 5d | 2028-03-14 | 2028-03-20 | 667 | C. Beaumont4; D. Kowalczyk5 |
| 669 | 6.0.6.2.3 | Training run cycle 2 (tuned) |  | 6d | 2028-03-21 | 2028-03-28 | 668 | D. Kowalczyk5; E. Delvecchio5; F. Solberg5; G. Nakashima5; H. Winfield5 |
| 670 | 6.0.6.2.4 | Training run cycle 3 (final) |  | 5d | 2028-03-29 | 2028-04-04 | 669 | H. Winfield5; I. Achebe5 |
| 671 | 6.0.6.3 | Bias & fairness evaluation |  | 8d | 2028-04-05 | 2028-04-14 | 666 | Z. Thompson; A. Okoro6 |
| 672 | 6.0.6.4 | Explainability & guardrail implementation |  | 8d | 2028-04-17 | 2028-04-26 | 671 | I. Achebe5; J. Larsen5 |
| 673 | 6.0.6.5 | Model documentation & model card |  | 6d | 2028-04-27 | 2028-05-04 | 672 | J. Larsen5; K. Sorensen5 |
| 674 | 6.0.6.6 | Model peer review (first line) |  | 5d | 2028-05-05 | 2028-05-11 | 673 | K. Sorensen5; L. Kessler4 |
| 675 | 6.0.7 | **Iterative Build (Sprints)** |  | 72d | 2028-03-06 | 2028-06-13 |  |  |
| 676 | 6.0.7.1 | **Sprint 1 — build & integrate** |  | 9d | 2028-03-06 | 2028-03-16 |  |  |
| 677 | 6.0.7.1.1 | Sprint 1 planning & backlog refinement | milestone | 1d | 2028-03-06 | 2028-03-06 |  | L. Kessler4; M. Rutherford4 |
| 678 | 6.0.7.1.2 | Sprint 1 feature & model development |  | 5d | 2028-03-07 | 2028-03-13 | 677 | M. Rutherford4; Z. Thompson; A. Okoro6; B. Whitby6; C. Beaumont4 |
| 679 | 6.0.7.1.3 | Sprint 1 code review & merge |  | 2d | 2028-03-14 | 2028-03-15 | 678 | C. Beaumont4; D. Kowalczyk5 |
| 680 | 6.0.7.1.4 | Sprint 1 demo, review & retrospective | milestone | 1d | 2028-03-16 | 2028-03-16 | 679 | D. Kowalczyk5; E. Delvecchio5 |
| 681 | 6.0.7.2 | **Sprint 2 — build & integrate** |  | 9d | 2028-03-17 | 2028-03-29 |  |  |
| 682 | 6.0.7.2.1 | Sprint 2 planning & backlog refinement | milestone | 1d | 2028-03-17 | 2028-03-17 | 676 | E. Delvecchio5; F. Solberg5 |
| 683 | 6.0.7.2.2 | Sprint 2 feature & model development |  | 5d | 2028-03-20 | 2028-03-24 | 682 | F. Solberg5; G. Nakashima5; H. Winfield5; I. Achebe5; J. Larsen5 |
| 684 | 6.0.7.2.3 | Sprint 2 code review & merge |  | 2d | 2028-03-27 | 2028-03-28 | 683 | J. Larsen5; K. Sorensen5 |
| 685 | 6.0.7.2.4 | Sprint 2 demo, review & retrospective | milestone | 1d | 2028-03-29 | 2028-03-29 | 684 | K. Sorensen5; L. Kessler4 |
| 686 | 6.0.7.3 | **Sprint 3 — build & integrate** |  | 9d | 2028-03-30 | 2028-04-11 |  |  |
| 687 | 6.0.7.3.1 | Sprint 3 planning & backlog refinement | milestone | 1d | 2028-03-30 | 2028-03-30 | 681 | L. Kessler4; M. Rutherford4 |
| 688 | 6.0.7.3.2 | Sprint 3 feature & model development |  | 5d | 2028-03-31 | 2028-04-06 | 687 | M. Rutherford4; Z. Thompson; A. Okoro6; B. Whitby6; C. Beaumont4 |
| 689 | 6.0.7.3.3 | Sprint 3 code review & merge |  | 2d | 2028-04-07 | 2028-04-10 | 688 | C. Beaumont4; D. Kowalczyk5 |
| 690 | 6.0.7.3.4 | Sprint 3 demo, review & retrospective | milestone | 1d | 2028-04-11 | 2028-04-11 | 689 | D. Kowalczyk5; E. Delvecchio5 |

| ID | WBS | Task | Type | Duration | Start | Finish | Predecessors | Resources |
| --- | --- | --- | --- | --- | --- | --- | --- | --- |
| 691 | 6.0.7.4 | **Sprint 4 — build & integrate** |  | 9d | 2028-04-12 | 2028-04-24 |  |  |
| 692 | 6.0.7.4.1 | Sprint 4 planning & backlog refinement | milestone | 1d | 2028-04-12 | 2028-04-12 | 686 | E. Delvecchio5; F. Solberg5 |
| 693 | 6.0.7.4.2 | Sprint 4 feature & model development |  | 5d | 2028-04-13 | 2028-04-19 | 692 | F. Solberg5; G. Nakashima5; H. Winfield5; I. Achebe5; J. Larsen5 |
| 694 | 6.0.7.4.3 | Sprint 4 code review & merge |  | 2d | 2028-04-20 | 2028-04-21 | 693 | J. Larsen5; K. Sorensen5 |
| 695 | 6.0.7.4.4 | Sprint 4 demo, review & retrospective | milestone | 1d | 2028-04-24 | 2028-04-24 | 694 | K. Sorensen5; L. Kessler4 |
| 696 | 6.0.7.5 | **Sprint 5 — build & integrate** |  | 9d | 2028-04-25 | 2028-05-05 |  |  |
| 697 | 6.0.7.5.1 | Sprint 5 planning & backlog refinement | milestone | 1d | 2028-04-25 | 2028-04-25 | 691 | L. Kessler4; M. Rutherford4 |
| 698 | 6.0.7.5.2 | Sprint 5 feature & model development |  | 5d | 2028-04-26 | 2028-05-02 | 697 | M. Rutherford4; Z. Thompson; A. Okoro6; B. Whitby6; C. Beaumont4 |
| 699 | 6.0.7.5.3 | Sprint 5 code review & merge |  | 2d | 2028-05-03 | 2028-05-04 | 698 | C. Beaumont4; D. Kowalczyk5 |
| 700 | 6.0.7.5.4 | Sprint 5 demo, review & retrospective | milestone | 1d | 2028-05-05 | 2028-05-05 | 699 | D. Kowalczyk5; E. Delvecchio5 |
| 701 | 6.0.7.6 | **Sprint 6 — build & integrate** |  | 9d | 2028-05-08 | 2028-05-18 |  |  |
| 702 | 6.0.7.6.1 | Sprint 6 planning & backlog refinement | milestone | 1d | 2028-05-08 | 2028-05-08 | 696 | E. Delvecchio5; F. Solberg5 |
| 703 | 6.0.7.6.2 | Sprint 6 feature & model development |  | 5d | 2028-05-09 | 2028-05-15 | 702 | F. Solberg5; G. Nakashima5; H. Winfield5; I. Achebe5; J. Larsen5 |
| 704 | 6.0.7.6.3 | Sprint 6 code review & merge |  | 2d | 2028-05-16 | 2028-05-17 | 703 | J. Larsen5; K. Sorensen5 |
| 705 | 6.0.7.6.4 | Sprint 6 demo, review & retrospective | milestone | 1d | 2028-05-18 | 2028-05-18 | 704 | K. Sorensen5; L. Kessler4 |
| 706 | 6.0.7.7 | **Sprint 7 — build & integrate** |  | 9d | 2028-05-19 | 2028-05-31 |  |  |
| 707 | 6.0.7.7.1 | Sprint 7 planning & backlog refinement | milestone | 1d | 2028-05-19 | 2028-05-19 | 701 | L. Kessler4; M. Rutherford4 |
| 708 | 6.0.7.7.2 | Sprint 7 feature & model development |  | 5d | 2028-05-22 | 2028-05-26 | 707 | M. Rutherford4; Z. Thompson; A. Okoro6; B. Whitby6; C. Beaumont4 |
| 709 | 6.0.7.7.3 | Sprint 7 code review & merge |  | 2d | 2028-05-29 | 2028-05-30 | 708 | C. Beaumont4; D. Kowalczyk5 |
| 710 | 6.0.7.7.4 | Sprint 7 demo, review & retrospective | milestone | 1d | 2028-05-31 | 2028-05-31 | 709 | D. Kowalczyk5; E. Delvecchio5 |
| 711 | 6.0.7.8 | **Sprint 8 — build & integrate** |  | 9d | 2028-06-01 | 2028-06-13 |  |  |
| 712 | 6.0.7.8.1 | Sprint 8 planning & backlog refinement | milestone | 1d | 2028-06-01 | 2028-06-01 | 706 | E. Delvecchio5; F. Solberg5 |
| 713 | 6.0.7.8.2 | Sprint 8 feature & model development |  | 5d | 2028-06-02 | 2028-06-08 | 712 | F. Solberg5; G. Nakashima5; H. Winfield5; I. Achebe5; J. Larsen5 |
| 714 | 6.0.7.8.3 | Sprint 8 code review & merge |  | 2d | 2028-06-09 | 2028-06-12 | 713 | J. Larsen5; K. Sorensen5 |
| 715 | 6.0.7.8.4 | Sprint 8 demo, review & retrospective | milestone | 1d | 2028-06-13 | 2028-06-13 | 714 | K. Sorensen5; L. Kessler4 |

| ID | WBS | Task | Duration | Start | Finish | Predecessors | Resources |
| --- | --- | --- | --- | --- | --- | --- | --- |
| 716 | 6.0.8 | **Integration & Environment Build** | 42d | 2028-03-27 | 2028-05-23 |  |  |
| 717 | 6.0.8.1 | **Application & workflow integration** | 20d | 2028-03-27 | 2028-04-21 |  |  |
| 718 | 6.0.8.1.1 | API & service integration | 8d | 2028-03-27 | 2028-04-05 |  | L. Kessler4; M. Rutherford4; Z. Thompson; A. Okoro6; B. Whitby6 |
| 719 | 6.0.8.1.2 | Human-in-the-loop review workflow | 6d | 2028-04-06 | 2028-04-13 | 718 | B. Whitby6; C. Beaumont4 |
| 720 | 6.0.8.1.3 | Channel / UI integration | 6d | 2028-04-14 | 2028-04-21 | 719 | C. Beaumont4; D. Kowalczyk5 |
| 721 | 6.0.8.2 | MLOps deployment pipeline setup | 10d | 2028-04-24 | 2028-05-05 | 717 | W. Kumar; J. Restrepo |
| 722 | 6.0.8.3 | Environment build & configuration | 6d | 2028-05-08 | 2028-05-15 | 721 | A. Prescott; B. Fairweather; C. Sondheim; D. Marchetti; E. Whitcomb |
| 723 | 6.0.8.4 | Integration smoke test & stabilization | 6d | 2028-05-16 | 2028-05-23 | 722 | D. Kowalczyk5; E. Delvecchio5 |
| 724 | 6.0.9 | **Testing & QA** | 93d | 2028-04-17 | 2028-08-23 |  |  |
| 725 | 6.0.9.1 | Test strategy & plan | 6d | 2028-04-17 | 2028-04-24 |  | M. Washington (QA); N. Ferraro |
| 726 | 6.0.9.2 | Test case authoring & data setup | 10d | 2028-04-25 | 2028-05-08 | 725 | N. Ferraro; O. Delacroix; P. Vartan; Q. Halvorsen; R. Nakamura |
| 727 | 6.0.9.3 | Unit & component testing | 10d | 2028-05-09 | 2028-05-22 | 726 | R. Nakamura; S. Okoro; T. Whitby; U. Beaumont; V. Kowalczyk |
| 728 | 6.0.9.4 | Integration testing | 12d | 2028-05-23 | 2028-06-07 | 727 | V. Kowalczyk; W. Delvecchio; X. Solberg; Y. Nakashima (QA); Z. Winfield (QA) [90%] |
| 729 | 6.0.9.5 | **System & end-to-end testing** | 12d | 2028-06-08 | 2028-06-23 |  |  |
| 730 | 6.0.9.5.1 | Functional E2E scenarios | 6d | 2028-06-08 | 2028-06-15 | 728 | V. Müller; J. Bennett; K. Garcia; L. Thompson; Z. Winfield (QA) [90%] |
| 731 | 6.0.9.5.2 | Negative & edge-case testing | 6d | 2028-06-16 | 2028-06-23 | 730 | L. Thompson; M. Washington (QA) |
| 732 | 6.0.9.6 | Model performance & regression testing | 10d | 2028-06-26 | 2028-07-07 | 729 | V. Müller; J. Bennett; K. Garcia |
| 733 | 6.0.9.7 | Security & penetration testing | 8d | 2028-07-10 | 2028-07-19 | 732 | N. Winthrop; O. Castillo; U. Kandel [90%]; V. Redmond [80%]; M. Hassan [20%] |
| 734 | 6.0.9.8 | Performance & load testing | 8d | 2028-07-20 | 2028-07-31 | 733 | M. Washington (QA); N. Ferraro |
| 735 | 6.0.9.9 | Defect triage & resolution cycles | 12d | 2028-08-01 | 2028-08-16 | 734 | K. Garcia; L. Thompson; M. Washington (QA); N. Ferraro; O. Delacroix |
| 736 | 6.0.9.10 | Test summary & exit report | 5d | 2028-08-17 | 2028-08-23 | 735 | N. Ferraro; O. Delacroix |
| 737 | 6.0.10 | **Independent Model Validation** | 27d | 2028-05-08 | 2028-06-13 |  |  |
| 738 | 6.0.10.1 | IMV submission & documentation review | 6d | 2028-05-08 | 2028-05-15 |  | X. Sorensen; Y. Larsen |
| 739 | 6.0.10.2 | **Independent performance & fairness validation** | 10d | 2028-05-16 | 2028-05-29 |  |  |
| 740 | 6.0.10.2.1 | Independent replication testing | 5d | 2028-05-16 | 2028-05-22 | 738 | Y. Larsen; Z. Winfield (IMV) |
| 741 | 6.0.10.2.2 | Fairness & bias re-testing | 5d | 2028-05-23 | 2028-05-29 | 740 | Z. Winfield (IMV); A. Kessler [90%] |
| 742 | 6.0.10.3 | Validation findings & remediation | 8d | 2028-05-30 | 2028-06-08 | 739 | P. Okafor; W. Achebe; X. Sorensen |
| 743 | 6.0.10.4 | IMV sign-off (production gate) | 3d | 2028-06-09 | 2028-06-13 | 742 | P. Okafor; A. Kessler [90%] |

| ID | WBS | Task | Duration | Start | Finish | Predecessors | Resources |
| --- | --- | --- | --- | --- | --- | --- | --- |
| 744 | 6.0.11 | **Compliance, Clinical & Controls Review** | 39d | 2028-05-29 | 2028-07-20 |  |  |
| 745 | 6.0.11.1 | Legal review (liability, disclaimers, contracts) | 6d | 2028-05-29 | 2028-06-05 |  | M. Bernstein; N. Harris; S. Patel [90%]; D. Flores [80%]; R. Thorne [20%] |
| 746 | 6.0.11.2 | Compliance & regulatory review | 8d | 2028-06-06 | 2028-06-15 | 745 | T. Jackson; R. Kimani [90%]; B. Cho [85%]; C. Morrison [80%]; U. Kowalski [80%] |
| 747 | 6.0.11.3 | Clinical / medical-policy review | 7d | 2028-06-16 | 2028-06-26 | 746 | K. Okoro; L. Delacroix [90%]; Dr. J. Whitby [80%]; Dr. I. Alvarado [50%]; Dr. N. Patel [25%] |
| 748 | 6.0.11.4 | SOX / financial-controls testing | 6d | 2028-06-27 | 2028-07-04 | 747 | N. Brennan; P. Whitcomb; O. Fairweather [90%]; Q. Marchetti [80%]; K. Williams [25%] |
| 749 | 6.0.11.5 | Data privacy audit & DPIA | 6d | 2028-07-05 | 2028-07-12 | 748 | O. Whitlock; P. Sandoval [90%] |
| 750 | 6.0.11.6 | Cybersecurity controls assurance | 6d | 2028-07-13 | 2028-07-20 | 749 | O. Castillo; P. Halstead |
| 751 | 6.0.12 | **User Acceptance Testing** | 49d | 2028-06-19 | 2028-08-24 |  |  |
| 752 | 6.0.12.1 | UAT planning & environment readiness | 6d | 2028-06-19 | 2028-06-26 |  | H. Solberg7 [80%]; I. Nakashima7 [70%]; E. Beaumont6 [50%]; F. Kowalczyk7 [50%]; G. Delvecchio7 [50%] |
| 753 | 6.0.12.2 | UAT test scenario authoring | 8d | 2028-06-27 | 2028-07-06 | 752 | Y. Sorensen6; I. Nakashima7 [70%]; Z. Kessler5 [50%]; A. Rutherford5 [50%]; B. Alvarado5 [50%] |
| 754 | 6.0.12.3 | **UAT execution cycles** | 20d | 2028-07-07 | 2028-08-03 |  |  |
| 755 | 6.0.12.3.1 | UAT cycle 1 | 6d | 2028-07-07 | 2028-07-14 | 753 | B. Alvarado5 [50%]; C. Whitby8 [50%]; D. Okoro8 [50%]; E. Beaumont6 [50%]; F. Kowalczyk7 [50%] |
| 756 | 6.0.12.3.2 | UAT defect fixes & retest | 5d | 2028-07-17 | 2028-07-21 | 755 | Y. Sorensen6; H. Solberg7 [80%]; I. Nakashima7 [70%]; F. Kowalczyk7 [50%]; G. Delvecchio7 [50%] |
| 757 | 6.0.12.3.3 | UAT cycle 2 (regression) | 5d | 2028-07-24 | 2028-07-28 | 756 | Y. Sorensen6; Z. Kessler5 [50%]; A. Rutherford5 [50%]; B. Alvarado5 [50%]; C. Whitby8 [50%] |
| 758 | 6.0.12.3.4 | Final UAT confirmation | 4d | 2028-07-31 | 2028-08-03 | 757 | C. Whitby8 [50%]; D. Okoro8 [50%]; E. Beaumont6 [50%]; F. Kowalczyk7 [50%]; G. Delvecchio7 [50%] |
| 759 | 6.0.12.4 | Business process & runbook validation | 6d | 2028-08-04 | 2028-08-11 | 754 | E. Whitcomb; F. Talbot; G. Restrepo; H. Vartan; I. Halvorsen [80%] |
| 760 | 6.0.12.5 | Operational readiness assessment | 6d | 2028-08-14 | 2028-08-21 | 759 | X. Larsen6; N. Alvarado4; V. Winfield6 [80%]; W. Achebe6 [70%]; M. Washington (CustOps) [20%] |
| 761 | 6.0.12.6 | UAT sign-off | 3d | 2028-08-22 | 2028-08-24 | 760 | H. Solberg7 [80%]; G. Delvecchio7 [50%] |
| 762 | 6.0.13 | **Change Management & Adoption** | 55d | 2028-07-10 | 2028-09-22 |  |  |
| 763 | 6.0.13.1 | Change impact assessment & stakeholder analysis | 7d | 2028-07-10 | 2028-07-18 |  | E. Winthrop [90%]; F. Achebe [80%] |
| 764 | 6.0.13.2 | **Training material development** | 10d | 2028-07-19 | 2028-08-01 |  |  |
| 765 | 6.0.13.2.1 | End-user training curriculum | 5d | 2028-07-19 | 2028-07-25 | 763 | F. Achebe [80%]; H. Kandel [70%] |
| 766 | 6.0.13.2.2 | Job aids & quick-reference | 5d | 2028-07-26 | 2028-08-01 | 765 | I. Redmond [80%]; H. Kandel [70%] |
| 767 | 6.0.13.3 | Training delivery & enablement | 12d | 2028-08-02 | 2028-08-17 | 764 | G. Okonkwo; B. Prescott; C. Whitfield; D. Solis; I. Redmond [80%] |
| 768 | 6.0.13.4 | Communications campaign | 8d | 2028-08-18 | 2028-08-29 | 767 | R. Castellanos [90%]; S. Halloway [80%]; T. Ainslie [70%]; B. Sullivan [30%] |
| 769 | 6.0.13.5 | Frontline readiness & super-user network | 8d | 2028-08-30 | 2028-09-08 | 768 | N. Alvarado4; O. Whitby7; P. Okoro7; Q. Beaumont5; R. Kowalczyk6 [90%] |
| 770 | 6.0.13.6 | Adoption tracking & reinforcement | 10d | 2028-09-11 | 2028-09-22 | 769 | D. Solis; E. Winthrop [90%] |

| ID | WBS | Task | Duration | Start | Finish | Predecessors | Resources |
| --- | --- | --- | --- | --- | --- | --- | --- |
| 771 | 6.0.14 | **Pilot Deployment** | 40d | 2028-07-31 | 2028-09-22 |  |  |
| 772 | 6.0.14.1 | Pilot readiness review & go/no-go | 4d | 2028-07-31 | 2028-08-03 |  | E. Delvecchio5; F. Solberg5 |
| 773 | 6.0.14.2 | Controlled pilot rollout | 12d | 2028-08-04 | 2028-08-21 | 772 | F. Solberg5; G. Nakashima5; H. Winfield5; I. Achebe5; J. Larsen5 |
| 774 | 6.0.14.3 | Pilot monitoring & tuning | 10d | 2028-08-22 | 2028-09-04 | 773 | A. Okoro6; B. Whitby6; C. Beaumont4 |
| 775 | 6.0.14.4 | Pilot support & issue resolution | 10d | 2028-09-05 | 2028-09-18 | 774 | S. Delvecchio6; T. Solberg6; R. Kowalczyk6 [90%]; U. Nakashima6 [80%]; V. Winfield6 [80%] |
| 776 | 6.0.14.5 | Pilot evaluation & production decision | 4d | 2028-09-19 | 2028-09-22 | 775 | J. Larsen5; K. Sorensen5 |
| 777 | 6.0.15 | **Production Deployment & Hypercare** | 48d | 2028-08-21 | 2028-10-25 |  |  |
| 778 | 6.0.15.1 | Production readiness review (3 boards) | 5d | 2028-08-21 | 2028-08-25 |  | K. Sorensen5; L. Kessler4 |
| 779 | 6.0.15.2 | Production cutover & go-live | 6d | 2028-08-28 | 2028-09-04 | 778 | Z. Thompson; A. Okoro6; B. Whitby6; C. Beaumont4; D. Kowalczyk5 |
| 780 | 6.0.15.3 | **Hypercare & stabilization** | 15d | 2028-09-05 | 2028-09-25 |  |  |
| 781 | 6.0.15.3.1 | Hypercare monitoring | 8d | 2028-09-05 | 2028-09-14 | 779 | L. Kessler4; M. Rutherford4; Z. Thompson; A. Okoro6; B. Whitby6 |
| 782 | 6.0.15.3.2 | Incident response & fixes | 7d | 2028-09-15 | 2028-09-25 | 781 | B. Whitby6; C. Beaumont4; D. Kowalczyk5; E. Delvecchio5; F. Solberg5 |
| 783 | 6.0.15.4 | Post-go-live service desk support | 12d | 2028-09-26 | 2028-10-11 | 780 | X. Larsen6; N. Alvarado4; V. Winfield6 [80%]; W. Achebe6 [70%]; M. Washington (CustOps) [20%] |
| 784 | 6.0.15.5 | Benefits baseline established | 4d | 2028-10-12 | 2028-10-17 | 783 | Z. Thompson; A. Okoro6 |
| 785 | 6.0.15.6 | Transition to steady-state operations | 6d | 2028-10-18 | 2028-10-25 | 784 | I. Halvorsen [80%]; H. Nakamura [30%] |
| 786 | 7.0 | **Optimization, Benefits & Closeout** | 169d | 2029-01-05 | 2029-08-29 |  |  |
| 787 | 7.0.1 | **Model Optimization & Retraining** | 73d | 2029-01-05 | 2029-04-17 |  |  |
| 788 | 7.0.1.1 | Cross-BRD model performance review | 12d | 2029-01-05 | 2029-01-22 |  | A. Reyes; J. Ferraro; M. Delacroix |
| 789 | 7.0.1.2 | **Retraining & optimization cycles** | 22d | 2029-01-23 | 2029-02-21 |  |  |
| 790 | 7.0.1.2.1 | BRD-01 model retraining | 7d | 2029-01-23 | 2029-01-31 | 788 | V. Kessler2; W. Rutherford2; X. Alvarado2; Y. Whitby3; Z. Okoro3 |
| 791 | 7.0.1.2.2 | BRD-02 model retraining | 7d | 2029-02-01 | 2029-02-09 | 790 | S. Whitby5; T. Okoro5; V. Vartan4; R. Alvarado3 [80%]; U. Delacroix4 [80%] |
| 792 | 7.0.1.2.3 | BRD-03 model retraining | 8d | 2029-02-12 | 2029-02-21 | 791 | F. Solberg5; G. Nakashima5; H. Winfield5; I. Achebe5; J. Larsen5 |
| 793 | 7.0.1.3 | Drift remediation & tuning | 15d | 2029-02-22 | 2029-03-14 | 789 | J. Restrepo; K. Vartan; L. Sondheim; M. Marchetti; N. Whitcomb |
| 794 | 7.0.1.4 | Model governance re-validation (IMV) | 12d | 2029-03-15 | 2029-03-30 | 793 | P. Okafor; W. Achebe; X. Sorensen |
| 795 | 7.0.1.5 | Prompt / rules optimization & A-B testing | 12d | 2029-04-02 | 2029-04-17 | 794 | F. Bennett; C. Garcia2; D. Thompson2 |

| ID | WBS | Task | Duration | Start | Finish | Predecessors | Resources |
| --- | --- | --- | --- | --- | --- | --- | --- |
| 796 | 7.0.2 | **Platform & Cost Optimization** | 40d | 2029-01-30 | 2029-03-26 |  |  |
| 797 | 7.0.2.1 | Compute & token cost optimization | 15d | 2029-01-30 | 2029-02-19 |  | N. Whitcomb; O. Talbot; P. Restrepo2 |
| 798 | 7.0.2.2 | Architecture simplification & tech-debt reduction | 15d | 2029-02-20 | 2029-03-12 | 797 | F. Okonkwo; G. Petrova; H. Delgado; I. Suzuki; J. Kowalczyk |
| 799 | 7.0.2.3 | License & vendor rationalization | 10d | 2029-03-13 | 2029-03-26 | 798 | I. Merchant [80%]; L. Park [80%] |
| 800 | 7.0.3 | **Benefits Realization & Audit** | 45d | 2029-02-22 | 2029-04-25 |  |  |
| 801 | 7.0.3.1 | Benefits tracking & measurement framework | 12d | 2029-02-22 | 2029-03-09 |  | A. Rodriguez; B. Halvorsen |
| 802 | 7.0.3.2 | Benefits data collection & validation | 15d | 2029-03-12 | 2029-03-30 | 801 | B. Halvorsen; C. Restrepo; D. Vartan; E. Talbot [90%]; F. Sondheim [80%] |
| 803 | 7.0.3.3 | Benefits realization audit | 10d | 2029-04-02 | 2029-04-13 | 802 | A. Rodriguez; F. Sondheim [80%] |
| 804 | 7.0.3.4 | Financial reconciliation & reporting | 8d | 2029-04-16 | 2029-04-25 | 803 | M. Osei; N. Brennan; P. Whitcomb; O. Fairweather [90%]; K. Williams [25%] |
| 805 | 7.0.4 | **Knowledge Transfer & Transition** | 82d | 2029-03-19 | 2029-07-10 |  |  |
| 806 | 7.0.4.1 | **Knowledge transfer to ACME teams** | 20d | 2029-03-19 | 2029-04-13 |  |  |
| 807 | 7.0.4.1.1 | Platform & MLOps knowledge transfer | 10d | 2029-03-19 | 2029-03-30 |  | N. Whitcomb; O. Talbot; P. Restrepo2; Q. Halvorsen2; R. Bianchi |
| 808 | 7.0.4.1.2 | Governance & model knowledge transfer | 10d | 2029-04-02 | 2029-04-13 | 807 | M. Delacroix; C. Alvarez; T. Nakamura; R. Osei; P. Singh [90%] |
| 809 | 7.0.4.2 | Customer Service Operations enablement | 15d | 2029-04-16 | 2029-05-04 | 806 | N. Alvarado4; O. Whitby7; P. Okoro7; Q. Beaumont5; R. Kowalczyk6 [90%] |
| 810 | 7.0.4.3 | Documentation & runbook finalization | 12d | 2029-05-07 | 2029-05-22 | 809 | A. Prescott; B. Fairweather; C. Sondheim; D. Marchetti; H. Nakamura [30%] |
| 811 | 7.0.4.4 | Steady-state operations transition | 15d | 2029-05-23 | 2029-06-12 | 810 | R. Bianchi; S. Fitzgerald; T. Andersen |
| 812 | 7.0.4.5 | Independent ACME operation period (≥ 4 weeks) | 20d | 2029-06-13 | 2029-07-10 | 811 | S. Delvecchio6; T. Solberg6; R. Kowalczyk6 [90%]; U. Nakashima6 [80%]; V. Winfield6 [80%] |
| 813 | 7.0.5 | **Organizational Transition** | 37d | 2029-04-11 | 2029-05-31 |  |  |
| 814 | 7.0.5.1 | Role transition & workforce redeployment | 15d | 2029-04-11 | 2029-05-01 |  | F. Bianchi; E. Marsh [90%]; G. Solberg [80%]; H. Rutherford [70%]; C. Johnson [20%] |
| 815 | 7.0.5.2 | Consultant roll-off & access decommissioning | 10d | 2029-05-02 | 2029-05-15 | 814 | D. Ferraro; C. Johnson [20%] |
| 816 | 7.0.5.3 | Final change & adoption reinforcement | 12d | 2029-05-16 | 2029-05-31 | 815 | G. Okonkwo; E. Winthrop [90%]; F. Achebe [80%]; I. Redmond [80%]; H. Kandel [70%] |
| 817 | 7.0.6 | **Continuous Improvement & Innovation** | 46d | 2029-05-04 | 2029-07-06 |  |  |
| 818 | 7.0.6.1 | Use-case backlog review & prioritization | 12d | 2029-05-04 | 2029-05-21 |  | R. Osei; V. Castellano; L. Whitfield; D. Ibrahim; K. Novak [80%] |
| 819 | 7.0.6.2 | Emerging AI capability evaluation | 12d | 2029-05-22 | 2029-06-06 | 818 | S. Khurana; A. Reyes; J. Ferraro |
| 820 | 7.0.6.3 | Process improvement from operational feedback | 12d | 2029-06-07 | 2029-06-22 | 819 | X. Larsen6; N. Alvarado4; V. Winfield6 [80%]; W. Achebe6 [70%]; M. Washington (CustOps) [20%] |
| 821 | 7.0.6.4 | Customer experience measurement & NPS analysis | 10d | 2029-06-25 | 2029-07-06 | 820 | J. Lee; U. Marchetti; V. Okwuosa |

| ID | WBS | Task | Duration | Start | Finish | Predecessors | Resources |
| --- | --- | --- | --- | --- | --- | --- | --- |
| 822 | 7.0.7 | **Program Closeout** | 67d | 2029-05-29 | 2029-08-29 |  |  |
| 823 | 7.0.7.1 | Closeout report & performance summary | 8d | 2029-05-29 | 2029-06-07 |  | H. Kim; V. Patel [80%]; G. Brown [60%] |
| 824 | 7.0.7.2 | Financial close & contingency return | 8d | 2029-06-08 | 2029-06-19 | 823 | A. Rodriguez; B. Halvorsen; C. Restrepo |
| 825 | 7.0.7.3 | Lessons learned consolidation | 6d | 2029-06-20 | 2029-06-27 | 824 | C. Tyrrell; Q. Wilson [80%]; G. Brown [60%] |
| 826 | 7.0.7.4 | Contract & vendor closeout | 6d | 2029-06-28 | 2029-07-05 | 825 | G. Ainsley; L. Park [80%] |
| 827 | 7.0.7.5 | Records archival & audit pack | 6d | 2029-08-06 | 2029-08-13 |  | C. Tyrrell; M. Kavanagh [15%] |
| 828 | 7.0.7.6 | Final communications & recognition | 4d | 2029-08-17 | 2029-08-22 |  | S. Halloway [80%]; T. Ainslie [70%] |
| 829 | 7.0.7.7 | Program closeout approval (ESB) | 3d | 2029-08-27 | 2029-08-29 |  | C. Tyrrell; M. Kavanagh [15%] |
